# ED SCHEDULE 3-25-16 SZ

Schedule from MS Project, 2019-06-10 to 2024-01-17, status date 2019-09-25, A marks actual dates.

## Calendars

- Standard: Mon-Fri 08:00-12:00, 13:00-17:00; Sat-Sun off.

## Resources

| Resource | Group |
| --- | --- |
| GC | General Contractor |
| OWNER | Owner |
| IOR | Inspector of Record |
| CASEWORK | Casework |
| STEEL | Secondary Steel/Unistrut |
| SPECIALTIES | Specialties |
| ACOUSTICAL CEILING | Acoustical Ceiling |
| DOORS | Doors, Frames, Hardware |
| ELECTRICAL | Electrical |
| MECHANICAL | HVAC, Plumbing |
| FIRE SPRINKLER | Fire Sprinkler |
| FIRE ALARM | Fire Alarm |
| FIREPROOF | Fireproofing, Firestopping |
| FLOORING | Flooring |
| NURSE CALL/INTERCOM | Nurse Call, Clocks, Intercom, Paging |
| DRYWALL/FRAMING | Drywall, Framing |
| LOW VOLTAGE | Low Voltage, Data/Com |
| PAINT | Paint |
| EPOXY FLOORS | Epoxy Floors |
| DEMO | Demolition |
| SAWCUT | Coring/Sawcutting |
| AOR | Architect |
| CONCRETE |  |

## Schedule

| ID | WBS | Task | Type | Duration | Start | Finish | Predecessors | Complete | Remaining | Baseline start | Baseline finish | Baseline duration | Total slack | Free slack | Constraint | Resources | Work | Actual work |
| --- | --- | --- | --- | --- | --- | --- | --- | --- | --- | --- | --- | --- | --- | --- | --- | --- | --- | --- |
| 1 | 1 | release given for priority submittals |  | 4d | 2019-06-10 A | 2019-06-13 A |  | 100% |  | 2019-06-10 | 2019-06-13 | 4d |  |  | start no earlier than 2019-06-10 | GC | 32h | 32h |
| 2 | 2 | ed ntp received | milestone | 0d | 2019-06-28 A | 2019-06-28 A |  | 100% |  | 2019-06-28 | 2019-06-28 | 0d |  |  | start no earlier than 2019-06-28 | OWNER |  |  |
| 3 | 3 | contract with subs |  | 25d | 2019-07-01 A | 2019-08-02 A |  | 100% |  | 2019-07-01 | 2019-08-02 | 25d |  |  | start no earlier than 2019-07-01 | GC | 200h | 200h |
| 4 | 4 | **submittals** |  | 78.5d | 2019-08-05 A | 2019-11-21 | 1, 3 | 55% | 35.14d | 2019-08-05 | 2019-11-21 | 78.5d | 1009d | 859d |  |  | 8960h | 4949.6h |
| 5 | 4.1 | **lighting** |  | 71d | 2019-08-05 A | 2019-11-11 | 1 | 60% | 28.17d | 2019-08-05 | 2019-11-11 | 71d | 139d |  |  |  | 504h | 304h |
| 6 | 4.1.1 | submit by |  | 1d | 2019-08-05 A | 2019-08-05 A | 1 | 100% |  | 2019-08-05 | 2019-08-05 | 1d |  |  | start no earlier than 2017-11-23 | ELECTRICAL | 8h | 8h |
| 7 | 4.1.2 | review & approval |  | 8d | 2019-08-06 A | 2019-08-15 A | 6 | 100% |  | 2019-08-06 | 2019-08-15 | 8d |  |  | start no earlier than 2017-12-05 | AOR | 64h | 64h |
| 8 | 4.1.3 | review & approval |  | 11d | 2019-08-16 A | 2019-08-30 A | 7 | 100% |  | 2019-08-16 | 2019-08-30 | 11d |  |  | start no earlier than 2018-08-13 | OWNER | 88h | 88h |
| 9 | 4.1.4 | fabrication/shipping |  | 42d | 2019-09-02 A | 2019-11-08 | 8 | 43% | 24d | 2019-09-02 | 2019-11-08 | 42d | 139d | 0d | start no earlier than 2017-12-20 | ELECTRICAL | 336h | 144h |
| 10 | 4.1.5 | required on-site |  | 1d | 2019-11-11 | 2019-11-11 | 9 |  |  | 2019-11-11 | 2019-11-11 | 1d | 7.5d |  | start no earlier than 2018-02-28 | ELECTRICAL | 8h |  |
| 11 | 4.2 | **lighting controls** |  | 58.5d | 2019-08-05 A | 2019-10-24 | 1 | 46% | 31.56d | 2019-08-05 | 2019-10-24 | 58.5d | 151.5d |  |  |  | 304h | 140h |
| 12 | 4.2.1 | submit by |  | 1d | 2019-08-05 A | 2019-08-05 A | 1 | 100% |  | 2019-08-05 | 2019-08-05 | 1d |  |  | start no earlier than 2017-11-23 | ELECTRICAL | 8h | 8h |
| 13 | 4.2.2 | review & approval |  | 9d | 2019-08-06 A | 2019-08-16 A | 12 | 100% |  | 2019-08-06 | 2019-08-16 | 9d |  |  | start no earlier than 2018-01-08 | AOR | 72h | 72h |
| 14 | 4.2.3 | review & approval |  | 7d | 2019-08-19 A | 2019-09-25 A | 13 | 100% |  | 2019-08-19 | 2019-09-25 | 7d |  |  | start no earlier than 2018-01-14 | OWNER | 56h | 56h |
| 15 | 4.2.4 | fabrication/shipping |  | 20d | 2019-09-25 A | 2019-10-23 | 14 | 3% | 19.5d | 2019-09-25 | 2019-10-23 | 20d | 151.5d | 0d | start no earlier than 2017-12-19 | ELECTRICAL | 160h | 4h |
| 16 | 4.2.5 | required on-site |  | 1d | 2019-10-23 | 2019-10-24 | 15 |  |  | 2019-10-23 | 2019-10-24 | 1d | 20d |  | start no earlier than 2018-02-27 | ELECTRICAL | 8h |  |
| 17 | 4.3 | **hvac** |  | 59.5d | 2019-08-05 A | 2019-10-25 | 1 | 68% | 18.76d | 2019-08-05 | 2019-10-25 | 59.5d | 119.5d |  |  |  | 368h | 252h |
| 18 | 4.3.1 | submit by |  | 1d | 2019-08-05 A | 2019-08-05 A | 1 | 100% |  | 2019-08-05 | 2019-08-05 | 1d |  |  | start no earlier than 2017-11-26 | MECHANICAL | 8h | 8h |
| 19 | 4.3.2 | review & approval |  | 11d | 2019-08-06 A | 2019-08-20 A | 18 | 100% |  | 2019-08-06 | 2019-08-20 | 11d |  |  | start no earlier than 2018-08-01 | AOR | 88h | 88h |
| 20 | 4.3.3 | review & approval |  | 6d | 2019-08-21 A | 2019-08-28 A | 19 | 100% |  | 2019-08-21 | 2019-08-28 | 6d |  |  | start no earlier than 2018-08-16 | OWNER | 48h | 48h |
| 21 | 4.3.4 | fabrication/shipping |  | 27d | 2019-08-29 A | 2019-10-24 | 20 | 50% | 13.5d | 2019-08-29 | 2019-10-24 | 27d | 119.5d | 0d | start no earlier than 2018-08-24 | MECHANICAL | 216h | 108h |
| 22 | 4.3.5 | required on-site |  | 1d | 2019-10-24 | 2019-10-25 | 21 |  |  | 2019-10-24 | 2019-10-25 | 1d | 19d |  | start no earlier than 2018-10-23 | MECHANICAL | 8h |  |
| 23 | 4.4 | **hvac - controls** |  | 52d | 2019-08-05 A | 2019-10-15 | 1 | 56% | 22.75d | 2019-08-05 | 2019-10-15 | 52d | 127d |  |  |  | 256h | 144h |
| 24 | 4.4.1 | submit by |  | 1d | 2019-08-05 A | 2019-08-05 A | 1 | 100% |  | 2019-08-05 | 2019-08-05 | 1d |  |  | start no earlier than 2017-11-26 | MECHANICAL | 8h | 8h |
| 25 | 4.4.2 | review & approval |  | 5d | 2019-08-06 A | 2019-08-12 A | 24 | 100% |  | 2019-08-06 | 2019-08-12 | 5d |  |  | start no earlier than 2018-08-01 | AOR | 40h | 40h |
| 26 | 4.4.3 | review & approval |  | 8d | 2019-08-13 A | 2019-09-19 A | 25 | 100% |  | 2019-08-13 | 2019-09-19 | 8d |  |  | start no earlier than 2018-01-17 | OWNER | 64h | 64h |
| 27 | 4.4.4 | fabrication/shipping |  | 17d | 2019-09-20 A | 2019-10-14 | 26 | 24% | 13d | 2019-09-20 | 2019-10-14 | 17d | 127d | 0d | start no earlier than 2018-09-18 | MECHANICAL | 136h | 32h |
| 28 | 4.4.5 | required on-site |  | 1d | 2019-10-15 | 2019-10-15 | 27 |  |  | 2019-10-15 | 2019-10-15 | 1d | 26.5d |  | start no earlier than 2018-10-12 | MECHANICAL | 8h |  |

| ID | WBS | Task | Duration | Start | Finish | Predecessors | Complete | Remaining | Baseline start | Baseline finish | Baseline duration | Total slack | Free slack | Constraint | Resources | Work | Actual work |
| --- | --- | --- | --- | --- | --- | --- | --- | --- | --- | --- | --- | --- | --- | --- | --- | --- | --- |
| 29 | 4.5 | **hvac - fcu, cav, ef** | 63d | 2019-08-05 A | 2019-10-30 | 1 | 49% | 32.2d | 2019-08-05 | 2019-10-30 | 63d | 116d |  |  |  | 360h | 176h |
| 30 | 4.5.1 | submit by | 1d | 2019-08-05 A | 2019-08-05 A | 1 | 100% |  | 2019-08-05 | 2019-08-05 | 1d |  |  | start no earlier than 2017-11-26 | MECHANICAL | 8h | 8h |
| 31 | 4.5.2 | review & approval | 11d | 2019-08-06 A | 2019-08-20 A | 30 | 100% |  | 2019-08-06 | 2019-08-20 | 11d |  |  | start no earlier than 2018-08-01 | AOR | 88h | 88h |
| 32 | 4.5.3 | rev1 submit by | 1d | 2019-08-05 A | 2019-08-05 A | 1 | 100% |  | 2019-08-05 | 2019-08-05 | 1d |  |  | start no earlier than 2017-11-26 | MECHANICAL | 8h | 8h |
| 33 | 4.5.4 | rev1 review & approval | 3d | 2019-08-06 A | 2019-08-08 A | 32 | 100% |  | 2019-08-06 | 2019-08-08 | 3d |  |  | start no earlier than 2017-12-30 | AOR | 24h | 24h |
| 34 | 4.5.5 | rev1 review & approval | 11d | 2019-08-21 A | 2019-10-04 | 31, 33 | 55% | 5d | 2019-08-21 | 2019-10-04 | 11d | 116d | 0d | start no earlier than 2018-01-15 | OWNER | 88h | 48h |
| 35 | 4.5.6 | fabrication/shipping | 17d | 2019-10-07 | 2019-10-29 | 34 |  |  | 2019-10-07 | 2019-10-29 | 17d | 15.5d | 0d | start no earlier than 2018-10-04 | MECHANICAL | 136h |  |
| 36 | 4.5.7 | required on-site | 1d | 2019-10-30 | 2019-10-30 | 35 |  |  | 2019-10-30 | 2019-10-30 | 1d | 15.5d |  | start no earlier than 2018-10-29 | MECHANICAL | 8h |  |
| 37 | 4.6 | **power** | 62.5d | 2019-08-05 A | 2019-10-30 | 1 | 69% | 19.28d | 2019-08-05 | 2019-10-30 | 62.5d | 95.5d |  |  |  | 376h | 260h |
| 38 | 4.6.1 | submit by | 1d | 2019-08-05 A | 2019-08-05 A | 1 | 100% |  | 2019-08-05 | 2019-08-05 | 1d |  |  | start no earlier than 2017-11-29 | ELECTRICAL | 8h | 8h |
| 39 | 4.6.2 | review & approval | 8d | 2019-08-06 A | 2019-08-15 A | 38 | 100% |  | 2019-08-06 | 2019-08-15 | 8d |  |  | start no earlier than 2017-12-10 | AOR | 64h | 64h |
| 40 | 4.6.3 | review & approval | 10d | 2019-08-16 A | 2019-08-29 A | 39 | 100% |  | 2019-08-16 | 2019-08-29 | 10d |  |  | start no earlier than 2018-08-13 | OWNER | 80h | 80h |
| 41 | 4.6.4 | fabrication/shipping | 27d | 2019-08-30 A | 2019-10-29 | 40 | 50% | 13.5d | 2019-08-30 | 2019-10-29 | 27d | 95.5d | 0d | start no earlier than 2017-12-25 | ELECTRICAL | 216h | 108h |
| 42 | 4.6.5 | required on-site | 1d | 2019-10-29 | 2019-10-30 | 41 |  |  | 2019-10-29 | 2019-10-30 | 1d | 16d |  | start no earlier than 2018-02-04 | ELECTRICAL | 8h |  |
| 43 | 4.7 | **data/com & low voltage** | 67d | 2019-08-05 A | 2019-11-05 | 1 | 58% | 27.83d | 2019-08-05 | 2019-11-05 | 67d | 147.75d |  |  |  | 520h | 304h |
| 44 | 4.7.1 | submit by | 1d | 2019-08-05 A | 2019-08-05 A | 1 | 100% |  | 2019-08-05 | 2019-08-05 | 1d |  |  | start no earlier than 2017-12-06 | LOW VOLTAGE | 8h | 8h |
| 45 | 4.7.2 | review & approval | 13d | 2019-08-06 A | 2019-08-22 A | 44 | 100% |  | 2019-08-06 | 2019-08-22 | 13d |  |  | start no earlier than 2017-12-22 | AOR | 104h | 104h |
| 46 | 4.7.3 | review & approval | 16d | 2019-08-23 A | 2019-09-13 A | 45 | 100% |  | 2019-08-23 | 2019-09-13 | 16d |  |  | start no earlier than 2018-08-20 | OWNER | 128h | 128h |
| 47 | 4.7.4 | fabrication/shipping | 34d | 2019-09-16 A | 2019-11-04 | 46 | 24% | 26d | 2019-09-16 | 2019-11-04 | 34d | 147.75d | 0d | start no earlier than 2018-01-06 | LOW VOLTAGE | 272h | 64h |
| 48 | 4.7.5 | required on-site | 1d | 2019-11-05 | 2019-11-05 | 47 |  |  | 2019-11-05 | 2019-11-05 | 1d | 11.5d |  | start no earlier than 2018-03-03 | LOW VOLTAGE | 8h |  |
| 49 | 4.8 | **doors** | 69d | 2019-08-05 A | 2019-11-07 | 1 | 35% | 44.56d | 2019-08-05 | 2019-11-07 | 69d | 176.75d |  |  |  | 384h | 136h |
| 50 | 4.8.1 | submit by | 1d | 2019-08-05 A | 2019-08-05 A | 1 | 100% |  | 2019-08-05 | 2019-08-05 | 1d |  |  | start no earlier than 2017-12-13 | DOORS | 8h | 8h |
| 51 | 4.8.2 | review & approval | 7d | 2019-08-06 A | 2019-08-14 A | 50 | 100% |  | 2019-08-06 | 2019-08-14 | 7d |  |  | start no earlier than 2017-12-25 | AOR | 56h | 56h |
| 52 | 4.8.3 | review & approval | 9d | 2019-08-15 A | 2019-09-25 A | 51 | 100% |  | 2019-08-15 | 2019-09-25 | 9d |  |  | start no earlier than 2018-01-14 | OWNER | 72h | 72h |
| 53 | 4.8.4 | fabrication/shipping | 30d | 2019-09-26 | 2019-11-06 | 52 |  |  | 2019-09-26 | 2019-11-06 | 30d | 9.5d | 0d | start no earlier than 2018-01-08 | DOORS | 240h |  |
| 54 | 4.8.5 | required on-site | 1d | 2019-11-07 | 2019-11-07 | 53 |  |  | 2019-11-07 | 2019-11-07 | 1d | 9.5d |  | start no earlier than 2018-03-06 | DOORS | 8h |  |

| ID | WBS | Task | Duration | Start | Finish | Predecessors | Complete | Remaining | Baseline start | Baseline finish | Baseline duration | Total slack | Free slack | Constraint | Resources | Work | Actual work |
| --- | --- | --- | --- | --- | --- | --- | --- | --- | --- | --- | --- | --- | --- | --- | --- | --- | --- |
| 55 | 4.9 | **plumbing** | 49.5d | 2019-08-05 A | 2019-10-11 | 1 | 57% | 21.08d | 2019-08-05 | 2019-10-11 | 49.5d | 103.5d |  |  |  | 216h | 124h |
| 56 | 4.9.1 | submit by | 1d | 2019-08-05 A | 2019-08-05 A | 1 | 100% |  | 2019-08-05 | 2019-08-05 | 1d |  |  | start no earlier than 2017-12-13 | MECHANICAL | 8h | 8h |
| 57 | 4.9.2 | review & approval | 11d | 2019-08-06 A | 2019-09-20 A | 56 | 100% |  | 2019-08-06 | 2019-09-20 | 11d |  |  | start no earlier than 2018-01-14 | AOR | 88h | 88h |
| 58 | 4.9.3 | review & approval | 2d | 2019-09-20 A | 2019-09-24 A | 57 | 100% |  | 2019-09-20 | 2019-09-24 | 2d |  |  | start no earlier than 2018-09-18 | OWNER | 16h | 16h |
| 59 | 4.9.4 | fabrication/shipping | 12d | 2019-09-24 A | 2019-10-10 | 58 | 13% | 10.5d | 2019-09-24 | 2019-10-10 | 12d | 103.5d | 0d | start no earlier than 2018-01-08 | MECHANICAL | 96h | 12h |
| 60 | 4.9.5 | required on-site | 1d | 2019-10-10 | 2019-10-11 | 59 |  |  | 2019-10-10 | 2019-10-11 | 1d | 29d |  | start no earlier than 2018-02-05 | MECHANICAL | 8h |  |
| 61 | 4.10 | **med gas** | 43.5d | 2019-08-05 A | 2019-10-03 | 1 | 76% | 10.4d | 2019-08-05 | 2019-10-03 | 43.5d | 109.5d |  |  |  | 184h | 140h |
| 62 | 4.10.1 | submit by | 1d | 2019-08-05 A | 2019-08-05 A | 1 | 100% |  | 2019-08-05 | 2019-08-05 | 1d |  |  | start no earlier than 2017-12-13 | MECHANICAL | 8h | 8h |
| 63 | 4.10.2 | review & approval | 7d | 2019-08-06 A | 2019-09-12 A | 62 | 100% |  | 2019-08-06 | 2019-09-12 | 7d |  |  | start no earlier than 2018-01-14 | AOR | 56h | 56h |
| 64 | 4.10.3 | review & approval | 2d | 2019-09-12 A | 2019-09-16 A | 63 | 100% |  | 2019-09-12 | 2019-09-16 | 2d |  |  | start no earlier than 2018-09-10 | OWNER | 16h | 16h |
| 65 | 4.10.4 | fabrication/shipping | 12d | 2019-09-16 A | 2019-10-02 | 64 | 63% | 4.5d | 2019-09-16 | 2019-10-02 | 12d | 109.5d | 0d | start no earlier than 2018-01-09 | MECHANICAL | 96h | 60h |
| 66 | 4.10.5 | required on-site | 1d | 2019-10-02 | 2019-10-03 | 65 |  |  | 2019-10-02 | 2019-10-03 | 1d | 35d |  | start no earlier than 2018-02-05 | MECHANICAL | 8h |  |
| 67 | 4.11 | **grid ceiling** | 64.3d | 2019-08-05 A | 2019-11-01 | 1 | 40% | 38.43d | 2019-08-05 | 2019-11-01 | 64.3d | 164.45d |  |  |  | 352h | 141.6h |
| 68 | 4.11.1 | submit by | 1d | 2019-08-05 A | 2019-08-05 A | 1 | 100% |  | 2019-08-05 | 2019-08-05 | 1d |  |  | start no earlier than 2017-12-19 | ACOUSTICAL CEILING | 8h | 8h |
| 69 | 4.11.2 | review & approval | 7d | 2019-08-06 A | 2019-08-15 A | 68 | 100% |  | 2019-08-06 | 2019-08-15 | 7d |  |  | start no earlier than 2018-01-03 | AOR | 56h | 56h |
| 70 | 4.11.3 | review & approval | 10d | 2019-08-15 A | 2019-09-26 | 69 | 97% | 0.3d | 2019-08-15 | 2019-09-26 | 10d | 164.45d | 0d | start no earlier than 2018-01-16 | OWNER | 80h | 77.6h |
| 71 | 4.11.4 | fabrication/shipping | 25d | 2019-09-26 | 2019-10-31 | 70 |  |  | 2019-09-26 | 2019-10-31 | 25d | 14.2d | 0d | start no earlier than 2018-01-14 | ACOUSTICAL CEILING | 200h |  |
| 72 | 4.11.5 | required on-site | 1d | 2019-10-31 | 2019-11-01 | 71 |  |  | 2019-10-31 | 2019-11-01 | 1d | 14.2d |  | start no earlier than 2018-02-26 | ACOUSTICAL CEILING | 8h |  |
| 73 | 4.12 | **lumicor partition panels** | 50.5d | 2019-08-05 A | 2019-10-14 | 1 | 63% | 18.57d | 2019-08-05 | 2019-10-14 | 50.5d | 199.25d |  |  |  | 272h | 172h |
| 74 | 4.12.1 | submit by | 1d | 2019-08-05 A | 2019-08-05 A | 1 | 100% |  | 2019-08-05 | 2019-08-05 | 1d |  |  | start no earlier than 2017-12-20 | CASEWORK | 8h | 8h |
| 75 | 4.12.2 | review & approval | 2d | 2019-08-06 A | 2019-08-30 A | 74 | 100% |  | 2019-08-06 | 2019-08-30 | 2d |  |  | start no earlier than 2018-01-16 | AOR | 16h | 16h |
| 76 | 4.12.3 | review & approval | 5d | 2019-08-30 A | 2019-09-06 A | 75 | 100% |  | 2019-08-30 | 2019-09-06 | 5d |  |  | start no earlier than 2018-08-27 | OWNER | 40h | 40h |
| 77 | 4.12.4 | fabrication/shipping | 25d | 2019-09-06 A | 2019-10-11 | 76 | 54% | 11.5d | 2019-09-06 | 2019-10-11 | 25d | 199.25d | 0d | start no earlier than 2018-01-16 | CASEWORK | 200h | 108h |
| 78 | 4.12.5 | required on-site | 1d | 2019-10-11 | 2019-10-14 | 77 |  |  | 2019-10-11 | 2019-10-14 | 1d | 28d |  | start no earlier than 2018-03-08 | CASEWORK | 8h |  |

| ID | WBS | Task | Duration | Start | Finish | Predecessors | Complete | Remaining | Baseline start | Baseline finish | Baseline duration | Total slack | Free slack | Constraint | Resources | Work | Actual work |
| --- | --- | --- | --- | --- | --- | --- | --- | --- | --- | --- | --- | --- | --- | --- | --- | --- | --- |
| 79 | 4.13 | **door frames** | 57.5d | 2019-08-05 A | 2019-10-23 | 2 | 41% | 33.98d | 2019-08-05 | 2019-10-23 | 57.5d | 93.5d |  |  |  | 264h | 108h |
| 80 | 4.13.1 | submit by | 1d | 2019-08-05 A | 2019-08-05 A | 3 | 100% |  | 2019-08-05 | 2019-08-05 | 1d |  |  | start no earlier than 2017-12-24 | DOORS | 8h | 8h |
| 81 | 4.13.2 | review & approval | 7d | 2019-08-06 A | 2019-08-14 A | 80 | 100% |  | 2019-08-06 | 2019-08-14 | 7d |  |  | start no earlier than 2018-01-02 | AOR | 56h | 56h |
| 82 | 4.13.3 | review & approval | 9d | 2019-08-15 A | 2019-10-01 | 81 | 61% | 3.5d | 2019-08-15 | 2019-10-01 | 9d | 93.5d | 0d | start no earlier than 2018-01-16 | OWNER | 72h | 44h |
| 83 | 4.13.4 | fabrication/shipping | 15d | 2019-10-01 | 2019-10-22 | 82 |  |  | 2019-10-01 | 2019-10-22 | 15d | 21d | 0d | start no earlier than 2018-01-15 | DOORS | 120h |  |
| 84 | 4.13.5 | required on-site | 1d | 2019-10-22 | 2019-10-23 | 83 |  |  | 2019-10-22 | 2019-10-23 | 1d | 21d |  | start no earlier than 2018-02-11 | DOORS | 8h |  |
| 85 | 4.14 | **casework** | 54.5d | 2019-08-05 A | 2019-10-18 | 2 | 51% | 26.45d | 2019-08-05 | 2019-10-18 | 54.5d | 197.25d |  |  |  | 272h | 140h |
| 86 | 4.14.1 | submit by | 1d | 2019-08-05 A | 2019-08-05 A | 3 | 100% |  | 2019-08-05 | 2019-08-05 | 1d |  |  | start no earlier than 2017-12-26 | CASEWORK | 8h | 8h |
| 87 | 4.14.2 | review & approval | 2d | 2019-08-06 A | 2019-09-05 A | 86 | 100% |  | 2019-08-06 | 2019-09-05 | 2d |  |  | start no earlier than 2018-01-16 | AOR | 16h | 16h |
| 88 | 4.14.3 | review & approval | 5d | 2019-09-05 A | 2019-09-12 A | 87 | 100% |  | 2019-09-05 | 2019-09-12 | 5d |  |  | start no earlier than 2018-10-15 | OWNER | 40h | 40h |
| 89 | 4.14.4 | fabrication/shipping | 25d | 2019-09-12 A | 2019-10-17 | 88 | 38% | 15.5d | 2019-09-12 | 2019-10-17 | 25d | 197.25d | 0d | start no earlier than 2018-01-24 | CASEWORK | 200h | 76h |
| 90 | 4.14.5 | required on-site | 1d | 2019-10-17 | 2019-10-18 | 89 |  |  | 2019-10-17 | 2019-10-18 | 1d | 24d |  | start no earlier than 2018-03-08 | CASEWORK | 8h |  |
| 91 | 4.15 | **door hardware** | 72.5d | 2019-08-05 A | 2019-11-13 | 2 | 28% | 52.11d | 2019-08-05 | 2019-11-13 | 72.5d | 175.25d |  |  |  | 384h | 108h |
| 92 | 4.15.1 | submit by | 1d | 2019-08-05 A | 2019-08-05 A | 3 | 100% |  | 2019-08-05 | 2019-08-05 | 1d |  |  | start no earlier than 2017-12-26 | DOORS | 8h | 8h |
| 93 | 4.15.2 | review & approval | 7d | 2019-08-06 A | 2019-08-14 A | 92 | 100% |  | 2019-08-06 | 2019-08-14 | 7d |  |  | start no earlier than 2018-01-02 | AOR | 56h | 56h |
| 94 | 4.15.3 | review & approval | 9d | 2019-08-15 A | 2019-10-01 | 93 | 61% | 3.5d | 2019-08-15 | 2019-10-01 | 9d | 175.25d | 0d | start no earlier than 2018-01-16 | OWNER | 72h | 44h |
| 95 | 4.15.4 | fabrication/shipping | 30d | 2019-10-01 | 2019-11-12 | 94 |  |  | 2019-10-01 | 2019-11-12 | 30d | 6d | 0d | start no earlier than 2018-01-15 | DOORS | 240h |  |
| 96 | 4.15.5 | required on-site | 1d | 2019-11-12 | 2019-11-13 | 95 |  |  | 2019-11-12 | 2019-11-13 | 1d | 6d |  | start no earlier than 2018-03-06 | DOORS | 8h |  |
| 97 | 4.16 | **ceiling tiles** | 78.5d | 2019-08-05 A | 2019-11-21 | 2 | 22% | 61.14d | 2019-08-05 | 2019-11-21 | 78.5d | 182.25d |  |  |  | 416h | 92h |
| 98 | 4.16.1 | submit by | 1d | 2019-08-05 A | 2019-08-05 A | 3 | 100% |  | 2019-08-05 | 2019-08-05 | 1d |  |  | start no earlier than 2017-12-30 | ACOUSTICAL CEILING | 8h | 8h |
| 99 | 4.16.2 | review & approval | 8d | 2019-08-06 A | 2019-08-15 A | 98 | 100% |  | 2019-08-06 | 2019-08-15 | 8d |  |  | start no earlier than 2018-01-05 | AOR | 64h | 64h |
| 100 | 4.16.3 | review & approval | 12d | 2019-08-16 A | 2019-10-09 | 99 | 21% | 9.5d | 2019-08-16 | 2019-10-09 | 12d | 182.25d | 0d | start no earlier than 2018-09-24 | OWNER | 96h | 20h |
| 101 | 4.16.4 | fabrication/shipping | 30d | 2019-10-09 | 2019-11-20 | 100 |  |  | 2019-10-09 | 2019-11-20 | 30d | 182.25d | 0d | start no earlier than 2018-01-26 | ACOUSTICAL CEILING | 240h |  |
| 102 | 4.16.5 | required on-site | 1d | 2019-11-20 | 2019-11-21 | 101 |  |  | 2019-11-20 | 2019-11-21 | 1d | 182.25d |  | start no earlier than 2018-03-10 | ACOUSTICAL CEILING | 8h |  |

| ID | WBS | Task | Duration | Start | Finish | Predecessors | Complete | Remaining | Baseline start | Baseline finish | Baseline duration | Total slack | Free slack | Constraint | Resources | Work | Actual work |
| --- | --- | --- | --- | --- | --- | --- | --- | --- | --- | --- | --- | --- | --- | --- | --- | --- | --- |
| 103 | 4.17 | **resilient flooring** | 62.5d | 2019-08-05 A | 2019-10-30 | 2 | 42% | 36.46d | 2019-08-05 | 2019-10-30 | 62.5d | 200.25d |  |  |  | 336h | 140h |
| 104 | 4.17.1 | submit by | 1d | 2019-08-05 A | 2019-09-03 A | 3 | 100% |  | 2019-08-05 | 2019-09-03 | 1d |  |  | start no earlier than 2018-01-17 | FLOORING | 8h | 8h |
| 105 | 4.17.2 | review & approval | 5d | 2019-09-03 A | 2019-09-10 A | 104 | 100% |  | 2019-09-03 | 2019-09-10 | 5d |  |  | start no earlier than 2018-01-15 | AOR | 40h | 40h |
| 106 | 4.17.3 | review & approval | 5d | 2019-09-10 A | 2019-09-17 A | 105 | 100% |  | 2019-09-10 | 2019-09-17 | 5d |  |  | start no earlier than 2018-10-18 | OWNER | 40h | 40h |
| 107 | 4.17.4 | fabrication/shipping | 30d | 2019-09-17 A | 2019-10-29 | 106 | 22% | 23.5d | 2019-09-17 | 2019-10-29 | 30d | 200.25d | 0d | start no earlier than 2018-01-29 | FLOORING | 240h | 52h |
| 108 | 4.17.5 | required on-site | 1d | 2019-10-29 | 2019-10-30 | 107 |  |  | 2019-10-29 | 2019-10-30 | 1d | 16d |  | start no earlier than 2018-03-13 | FLOORING | 8h |  |
| 109 | 4.18 | **metal framing** | 45d | 2019-08-05 A | 2019-10-04 | 2 | 63% | 16.58d | 2019-08-05 | 2019-10-04 | 45d | 82d |  |  |  | 152h | 96h |
| 110 | 4.18.1 | submit by | 1d | 2019-08-05 A | 2019-08-05 A | 3 | 100% |  | 2019-08-05 | 2019-08-05 | 1d |  |  | start no earlier than 2018-01-06 | DRYWALL/FRAMING | 8h | 8h |
| 111 | 4.18.2 | review & approval | 12d | 2019-08-06 A | 2019-09-26 | 110 | 92% | 1d | 2019-08-06 | 2019-09-26 | 12d | 82d | 0d | start no earlier than 2018-01-15 | AOR | 96h | 88h |
| 112 | 4.18.3 | review & approval | 5d | 2019-09-27 | 2019-10-03 | 111 |  |  | 2019-09-27 | 2019-10-03 | 5d | 33.5d | 0d | start no earlier than 2018-11-06 | OWNER | 40h |  |
| 113 | 4.18.4 | required on-site | 1d | 2019-10-04 | 2019-10-04 | 112 |  |  | 2019-10-04 | 2019-10-04 | 1d | 33.5d |  | start no earlier than 2018-02-03 | DRYWALL/FRAMING | 8h |  |
| 114 | 4.19 | **wall protection / handrails** | 64.5d | 2019-08-05 A | 2019-11-01 | 2 | 34% | 42.73d | 2019-08-05 | 2019-11-01 | 64.5d | 193.25d |  |  |  | 320h | 108h |
| 115 | 4.19.1 | submit by | 1d | 2019-08-05 A | 2019-08-05 A | 3 | 100% |  | 2019-08-05 | 2019-08-05 | 1d |  |  | start no earlier than 2018-01-06 | SPECIALTIES | 8h | 8h |
| 116 | 4.19.2 | review & approval | 4d | 2019-08-06 A | 2019-08-09 A | 115 | 100% |  | 2019-08-06 | 2019-08-09 | 4d |  |  | start no earlier than 2018-09-12 | AOR | 32h | 32h |
| 117 | 4.19.3 | review & approval | 9d | 2019-08-12 A | 2019-09-26 | 116 | 94% | 0.5d | 2019-08-12 | 2019-09-26 | 9d | 193.25d | 0d | start no earlier than 2018-01-15 | OWNER | 72h | 68h |
| 118 | 4.19.4 | fabrication/shipping | 25d | 2019-09-26 | 2019-10-31 | 117 |  |  | 2019-09-26 | 2019-10-31 | 25d | 14d | 0d | start no earlier than 2018-11-05 | SPECIALTIES | 200h |  |
| 119 | 4.19.5 | required on-site | 1d | 2019-10-31 | 2019-11-01 | 118 |  |  | 2019-10-31 | 2019-11-01 | 1d | 14d |  | start no earlier than 2018-12-10 | SPECIALTIES | 8h |  |
| 120 | 4.20 | **intercom/nurse call (deferred approval)** | 32d | 2019-08-05 A | 2019-09-17 A | 2 | 100% |  | 2019-08-05 | 2019-09-17 | 32d |  |  |  |  | 256h | 256h |
| 121 | 4.20.1 | submit by | 1d | 2019-08-05 A | 2019-08-05 A | 3 | 100% |  | 2019-08-05 | 2019-08-05 | 1d |  |  | start no earlier than 2018-01-09 | NURSE CALL/INTERCOM | 8h | 8h |
| 122 | 4.20.2 | review & approval | 10d | 2019-08-06 A | 2019-08-19 A | 121 | 100% |  | 2019-08-06 | 2019-08-19 | 10d |  |  | start no earlier than 2018-01-22 | AOR | 80h | 80h |
| 123 | 4.20.3 | oshpd field review | 10d | 2019-08-20 A | 2019-09-02 A | 122 | 100% |  | 2019-08-20 | 2019-09-02 | 10d |  |  | start no earlier than 2018-09-26 | IOR | 80h | 80h |
| 124 | 4.20.4 | fabrication/shipping | 10d | 2019-09-03 A | 2019-09-16 A | 123 | 100% |  | 2019-09-03 | 2019-09-16 | 10d |  |  | start no earlier than 2018-02-20 | NURSE CALL/INTERCOM | 80h | 80h |
| 125 | 4.20.5 | required on-site | 1d | 2019-09-17 A | 2019-09-17 A | 124 | 100% |  | 2019-09-17 | 2019-09-17 | 1d |  |  | start no earlier than 2018-03-06 | NURSE CALL/INTERCOM | 8h | 8h |
| 126 | 4.21 | **concrete/mix design** | 27.25d | 2019-08-05 A | 2019-09-11 A | 2 | 100% |  | 2019-08-05 | 2019-09-11 | 27.25d |  |  |  |  | 96h | 96h |
| 127 | 4.21.1 | submit by | 1d | 2019-08-05 A | 2019-08-27 A | 3 | 100% |  | 2019-08-05 | 2019-08-27 | 1d |  |  | start no earlier than 2018-01-13 | CONCRETE | 8h | 8h |
| 128 | 4.21.2 | review & approval | 5d | 2019-08-27 A | 2019-09-03 A | 127 | 100% |  | 2019-08-27 | 2019-09-03 | 5d |  |  | start no earlier than 2018-10-04 | AOR | 40h | 40h |
| 129 | 4.21.3 | review & approval | 5d | 2019-09-03 A | 2019-09-10 A | 128 | 100% |  | 2019-09-03 | 2019-09-10 | 5d |  |  | start no earlier than 2018-10-11 | OWNER | 40h | 40h |
| 130 | 4.21.4 | required on-site | 1d | 2019-09-10 A | 2019-09-11 A | 129 | 100% |  | 2019-09-10 | 2019-09-11 | 1d |  |  | start no earlier than 2018-10-18 | CONCRETE | 8h | 8h |

| ID | WBS | Task | Duration | Start | Finish | Predecessors | Complete | Remaining | Baseline start | Baseline finish | Baseline duration | Total slack | Free slack | Constraint | Resources | Work | Actual work |
| --- | --- | --- | --- | --- | --- | --- | --- | --- | --- | --- | --- | --- | --- | --- | --- | --- | --- |
| 131 | 4.22 | **wainscot installations** | 64.5d | 2019-08-05 A | 2019-11-01 | 2 | 34% | 42.73d | 2019-08-05 | 2019-11-01 | 64.5d | 209.25d |  |  |  | 320h | 108h |
| 132 | 4.22.1 | submit by | 1d | 2019-08-05 A | 2019-08-05 A | 3 | 100% |  | 2019-08-05 | 2019-08-05 | 1d |  |  | start no earlier than 2018-01-14 | SPECIALTIES | 8h | 8h |
| 133 | 4.22.2 | review & approval | 4d | 2019-08-06 A | 2019-08-09 A | 132 | 100% |  | 2019-08-06 | 2019-08-09 | 4d |  |  | start no earlier than 2018-01-27 | AOR | 32h | 32h |
| 134 | 4.22.3 | review & approval | 9d | 2019-08-12 A | 2019-09-26 | 133 | 94% | 0.5d | 2019-08-12 | 2019-09-26 | 9d | 209.25d | 0d | start no earlier than 2018-01-15 | OWNER | 72h | 68h |
| 135 | 4.22.4 | fabrication/shipping | 25d | 2019-09-26 | 2019-10-31 | 134 |  |  | 2019-09-26 | 2019-10-31 | 25d | 14d | 0d | start no earlier than 2018-02-13 | SPECIALTIES | 200h |  |
| 136 | 4.22.5 | required on-site | 1d | 2019-10-31 | 2019-11-01 | 135 |  |  | 2019-10-31 | 2019-11-01 | 1d | 14d |  | start no earlier than 2018-03-22 | SPECIALTIES | 8h |  |
| 137 | 4.23 | **restroom trimouts/toilet accessories** | 67.5d | 2019-08-05 A | 2019-11-06 | 2 | 31% | 46.31d | 2019-08-05 | 2019-11-06 | 67.5d | 217.25d |  |  |  | 344h | 108h |
| 138 | 4.23.1 | submit by | 1d | 2019-08-05 A | 2019-08-05 A | 3 | 100% |  | 2019-08-05 | 2019-08-05 | 1d |  |  | start no earlier than 2018-01-16 | SPECIALTIES | 8h | 8h |
| 139 | 4.23.2 | review & approval | 7d | 2019-08-06 A | 2019-08-14 A | 138 | 100% |  | 2019-08-06 | 2019-08-14 | 7d |  |  | start no earlier than 2018-01-29 | AOR | 56h | 56h |
| 140 | 4.23.3 | review & approval | 9d | 2019-08-15 A | 2019-10-01 | 139 | 61% | 3.5d | 2019-08-15 | 2019-10-01 | 9d | 217.25d | 0d | start no earlier than 2018-01-17 | OWNER | 72h | 44h |
| 141 | 4.23.4 | fabrication/shipping | 25d | 2019-10-01 | 2019-11-05 | 140 |  |  | 2019-10-01 | 2019-11-05 | 25d | 11d | 0d | start no earlier than 2018-02-13 | SPECIALTIES | 200h |  |
| 142 | 4.23.5 | required on-site | 1d | 2019-11-05 | 2019-11-06 | 141 |  |  | 2019-11-05 | 2019-11-06 | 1d | 11d |  | start no earlier than 2018-03-24 | SPECIALTIES | 8h |  |
| 143 | 4.24 | **fire sprinkler** | 39d | 2019-08-05 A | 2019-09-26 | 2 | 93% | 2.6d | 2019-08-05 | 2019-09-26 | 39d | 165d |  |  |  | 120h | 112h |
| 144 | 4.24.1 | submit by | 1d | 2019-08-05 A | 2019-08-05 A | 3 | 100% |  | 2019-08-05 | 2019-08-05 | 1d |  |  | start no earlier than 2018-02-03 | FIRE SPRINKLER | 8h | 8h |
| 145 | 4.24.2 | review & approval | 8d | 2019-08-06 A | 2019-09-18 A | 144 | 100% |  | 2019-08-06 | 2019-09-18 | 8d |  |  | start no earlier than 2018-01-15 | AOR | 64h | 64h |
| 146 | 4.24.3 | review & approval | 5d | 2019-09-19 A | 2019-09-25 A | 145 | 100% |  | 2019-09-19 | 2019-09-25 | 5d |  |  | start no earlier than 2018-10-29 | OWNER | 40h | 40h |
| 147 | 4.24.4 | required on-site | 1d | 2019-09-26 | 2019-09-26 | 146 |  |  | 2019-09-26 | 2019-09-26 | 1d | 39.5d |  | start no earlier than 2018-02-21 | FIRE SPRINKLER | 8h |  |
| 148 | 4.25 | **walls drywall** | 48.5d | 2019-08-05 A | 2019-10-10 | 2 | 45% | 26.8d | 2019-08-05 | 2019-10-10 | 48.5d | 168.25d |  |  |  | 152h | 68h |
| 149 | 4.25.1 | submit by | 1d | 2019-08-05 A | 2019-08-05 A | 3 | 100% |  | 2019-08-05 | 2019-08-05 | 1d |  |  | start no earlier than 2018-01-21 | DRYWALL/FRAMING | 8h | 8h |
| 150 | 4.25.2 | review & approval | 12d | 2019-08-06 A | 2019-10-02 | 149 | 63% | 4.5d | 2019-08-06 | 2019-10-02 | 12d | 168.25d | 0d | start no earlier than 2018-01-15 | AOR | 96h | 60h |
| 151 | 4.25.3 | review & approval | 5d | 2019-10-02 | 2019-10-09 | 150 |  |  | 2019-10-02 | 2019-10-09 | 5d | 30d | 0d | start no earlier than 2018-11-09 | OWNER | 40h |  |
| 152 | 4.25.4 | required on-site | 1d | 2019-10-09 | 2019-10-10 | 151 |  |  | 2019-10-09 | 2019-10-10 | 1d | 30d |  | start no earlier than 2018-02-18 | DRYWALL/FRAMING | 8h |  |
| 153 | 4.26 | **fire alarm** | 29.5d | 2019-08-05 A | 2019-09-13 A | 2 | 100% |  | 2019-08-05 | 2019-09-13 | 29.5d |  |  |  |  | 176h | 176h |
| 154 | 4.26.1 | submit by | 1d | 2019-08-05 A | 2019-08-15 A | 3 | 100% |  | 2019-08-05 | 2019-08-15 | 1d |  |  | start no earlier than 2018-01-23 | FIRE ALARM | 8h | 8h |
| 155 | 4.26.2 | review & approval | 5d | 2019-08-15 A | 2019-08-22 A | 154 | 100% |  | 2019-08-15 | 2019-08-22 | 5d |  |  | start no earlier than 2018-02-07 | AOR | 40h | 40h |
| 156 | 4.26.3 | review & approval | 5d | 2019-08-22 A | 2019-08-29 A | 155 | 100% |  | 2019-08-22 | 2019-08-29 | 5d |  |  | start no earlier than 2018-09-28 | OWNER | 40h | 40h |
| 157 | 4.26.4 | fabrication/shipping | 10d | 2019-08-29 A | 2019-09-12 A | 156 | 100% |  | 2019-08-29 | 2019-09-12 | 10d |  |  | start no earlier than 2018-02-22 | FIRE ALARM | 80h | 80h |
| 158 | 4.26.5 | required on-site | 1d | 2019-09-12 A | 2019-09-13 A | 157 | 100% |  | 2019-09-12 | 2019-09-13 | 1d |  |  | start no earlier than 2018-03-08 | FIRE ALARM | 8h | 8h |

| ID | WBS | Task | Duration | Start | Finish | Predecessors | Complete | Baseline start | Baseline finish | Baseline duration | Constraint | Resources | Work | Actual work |
| --- | --- | --- | --- | --- | --- | --- | --- | --- | --- | --- | --- | --- | --- | --- |
| 159 | 4.27 | **firestop/fireproofing** | 14.75d | 2019-08-05 A | 2019-08-23 A | 2 | 100% | 2019-08-05 | 2019-08-23 | 14.75d |  |  | 96h | 96h |
| 160 | 4.27.1 | submit by | 1d | 2019-08-05 A | 2019-08-08 A | 3 | 100% | 2019-08-05 | 2019-08-08 | 1d | start no earlier than 2018-01-30 | FIREPROOF | 8h | 8h |
| 161 | 4.27.2 | review & approval | 5d | 2019-08-08 A | 2019-08-15 A | 160 | 100% | 2019-08-08 | 2019-08-15 | 5d | start no earlier than 2018-02-14 | AOR | 40h | 40h |
| 162 | 4.27.3 | review & approval | 5d | 2019-08-15 A | 2019-08-22 A | 161 | 100% | 2019-08-15 | 2019-08-22 | 5d | start no earlier than 2018-09-21 | OWNER | 40h | 40h |
| 163 | 4.27.4 | required on-site | 1d | 2019-08-22 A | 2019-08-23 A | 162 | 100% | 2019-08-22 | 2019-08-23 | 1d | start no earlier than 2018-03-01 | FIREPROOF | 8h | 8h |
| 164 | 4.28 | **epoxy flooring** | 24.5d | 2019-08-05 A | 2019-09-06 A | 2 | 100% | 2019-08-05 | 2019-09-06 | 24.5d |  |  | 176h | 176h |
| 165 | 4.28.1 | submit by | 1d | 2019-08-05 A | 2019-08-08 A | 3 | 100% | 2019-08-05 | 2019-08-08 | 1d | start no earlier than 2018-01-30 | EPOXY FLOORS | 8h | 8h |
| 166 | 4.28.2 | review & approval | 5d | 2019-08-08 A | 2019-08-15 A | 165 | 100% | 2019-08-08 | 2019-08-15 | 5d | start no earlier than 2018-02-15 | AOR | 40h | 40h |
| 167 | 4.28.3 | review & approval | 5d | 2019-08-15 A | 2019-08-22 A | 166 | 100% | 2019-08-15 | 2019-08-22 | 5d | start no earlier than 2018-09-21 | OWNER | 40h | 40h |
| 168 | 4.28.4 | fabrication/shipping | 10d | 2019-08-22 A | 2019-09-05 A | 167 | 100% | 2019-08-22 | 2019-09-05 | 10d | start no earlier than 2018-03-01 | EPOXY FLOORS | 80h | 80h |
| 169 | 4.28.5 | required on-site | 1d | 2019-09-05 A | 2019-09-06 A | 168 | 100% | 2019-09-05 | 2019-09-06 | 1d | start no earlier than 2018-03-15 | EPOXY FLOORS | 8h | 8h |
| 170 | 4.29 | **paint** | 32.5d | 2019-08-05 A | 2019-09-18 A | 2 | 100% | 2019-08-05 | 2019-09-18 | 32.5d |  |  | 96h | 96h |
| 171 | 4.29.1 | submit by | 1d | 2019-08-05 A | 2019-08-05 A | 3 | 100% | 2019-08-05 | 2019-08-05 | 1d | start no earlier than 2018-02-04 | PAINT | 8h | 8h |
| 172 | 4.29.2 | review & approval | 5d | 2019-08-06 A | 2019-09-10 A | 171 | 100% | 2019-08-06 | 2019-09-10 | 5d | start no earlier than 2018-02-17 | AOR | 40h | 40h |
| 173 | 4.29.3 | review & approval | 5d | 2019-09-10 A | 2019-09-17 A | 172 | 100% | 2019-09-10 | 2019-09-17 | 5d | start no earlier than 2018-10-18 | OWNER | 40h | 40h |
| 174 | 4.29.4 | required on-site | 1d | 2019-09-17 A | 2019-09-18 A | 173 | 100% | 2019-09-17 | 2019-09-18 | 1d | start no earlier than 2018-03-04 | PAINT | 8h | 8h |
| 175 | 4.30 | **unistrut work** | 17d | 2019-08-05 A | 2019-08-27 A | 2 | 100% | 2019-08-05 | 2019-08-27 | 17d |  |  | 136h | 136h |
| 176 | 4.30.1 | submit by | 1d | 2019-08-05 A | 2019-08-05 A | 3 | 100% | 2019-08-05 | 2019-08-05 | 1d | start no earlier than 2018-02-10 | STEEL | 8h | 8h |
| 177 | 4.30.2 | review & approval | 5d | 2019-08-06 A | 2019-08-12 A | 176 | 100% | 2019-08-06 | 2019-08-12 | 5d | start no earlier than 2018-09-12 | AOR | 40h | 40h |
| 178 | 4.30.3 | review & approval | 5d | 2019-08-13 A | 2019-08-19 A | 177 | 100% | 2019-08-13 | 2019-08-19 | 5d | start no earlier than 2018-09-19 | OWNER | 40h | 40h |
| 179 | 4.30.4 | fabrication/shipping | 5d | 2019-08-20 A | 2019-08-26 A | 178 | 100% | 2019-08-20 | 2019-08-26 | 5d | start no earlier than 2018-09-26 | STEEL | 40h | 40h |
| 180 | 4.30.5 | required on-site | 1d | 2019-08-27 A | 2019-08-27 A | 179 | 100% | 2019-08-27 | 2019-08-27 | 1d | start no earlier than 2018-10-04 | STEEL | 8h | 8h |
| 181 | 4.31 | **clocks** | 32d | 2019-08-05 A | 2019-09-17 A | 2 | 100% | 2019-08-05 | 2019-09-17 | 32d |  |  | 256h | 256h |
| 182 | 4.31.1 | submit by | 1d | 2019-08-05 A | 2019-08-05 A | 3 | 100% | 2019-08-05 | 2019-08-05 | 1d | start no earlier than 2018-05-02 | NURSE CALL/INTERCOM | 8h | 8h |
| 183 | 4.31.2 | review & approval | 5d | 2019-08-06 A | 2019-08-12 A | 182 | 100% | 2019-08-06 | 2019-08-12 | 5d | start no earlier than 2018-02-18 | AOR | 40h | 40h |
| 184 | 4.31.3 | review & approval | 5d | 2019-08-13 A | 2019-08-19 A | 183 | 100% | 2019-08-13 | 2019-08-19 | 5d | start no earlier than 2018-09-19 | OWNER | 40h | 40h |
| 185 | 4.31.4 | fabrication/shipping | 20d | 2019-08-20 A | 2019-09-16 A | 184 | 100% | 2019-08-20 | 2019-09-16 | 20d | start no earlier than 2018-03-04 | NURSE CALL/INTERCOM | 160h | 160h |
| 186 | 4.31.5 | required on-site | 1d | 2019-09-17 A | 2019-09-17 A | 185 | 100% | 2019-09-17 | 2019-09-17 | 1d | start no earlier than 2018-03-18 | NURSE CALL/INTERCOM | 8h | 8h |

| ID | WBS | Task | Type | Duration | Start | Finish | Predecessors | Complete | Remaining | Baseline start | Baseline finish | Baseline duration | Total slack | Free slack | Constraint | Resources | Work | Actual work |
| --- | --- | --- | --- | --- | --- | --- | --- | --- | --- | --- | --- | --- | --- | --- | --- | --- | --- | --- |
| 187 | 4.32 | **privacy curtain** |  | 77.5d | 2019-08-05 A | 2019-11-20 | 2 | 36% | 49.38d | 2019-08-05 | 2019-11-20 | 77.5d | 1010d |  |  |  | 496h | 180h |
| 188 | 4.32.1 | submit by |  | 1d | 2019-08-05 A | 2019-08-05 A | 3 | 100% |  | 2019-08-05 | 2019-08-05 | 1d |  |  | start no earlier than 2018-07-08 | SPECIALTIES | 8h | 8h |
| 189 | 4.32.2 | review & approval |  | 5d | 2019-08-06 A | 2019-08-12 A | 188 | 100% |  | 2019-08-06 | 2019-08-12 | 5d |  |  | start no earlier than 2018-09-12 | AOR | 40h | 40h |
| 190 | 4.32.3 | review & approval |  | 5d | 2019-08-13 A | 2019-09-10 A | 189 | 100% |  | 2019-08-13 | 2019-09-10 | 5d |  |  | start no earlier than 2018-09-19 | OWNER | 40h | 40h |
| 191 | 4.32.4 | fabrication/shipping |  | 50d | 2019-09-10 A | 2019-11-19 | 190 | 23% | 38.5d | 2019-09-10 | 2019-11-19 | 50d | 1010d | 0d | start no earlier than 2018-10-18 | SPECIALTIES | 400h | 92h |
| 192 | 4.32.5 | required on-site |  | 1d | 2019-11-19 | 2019-11-20 | 191 |  |  | 2019-11-19 | 2019-11-20 | 1d | 1d |  | start no earlier than 2018-12-27 | SPECIALTIES | 8h |  |
| 193 | 5 | preconstruction air survey |  | 1d | 2019-11-27 A | 2019-11-27 A | 2, 4 | 100% |  | 2019-11-21 | 2019-11-28 | 5d |  |  | start no earlier than 2019-03-13 | MECHANICAL | 8h | 8h |
| 194 | 6 | preconstruction meeting | milestone | 0d | 2019-11-27 A | 2019-11-27 A | 2, 193 | 100% |  | 2019-11-28 | 2019-11-29 | 1d |  |  | start no earlier than 2019-03-12 | GC; OWNER |  |  |
| 195 | 7 | **phase 1 ed entry construction** |  | 220.75d | 2019-11-28 | 2020-10-01 | 194 |  |  | 2019-11-29 | 2020-10-05 | 220.75d | 0d |  |  |  | 1862h |  |
| 196 | 7.1 | infection control set up |  | 1d | 2019-11-28 | 2019-11-28 | 194, 193 |  |  | 2019-11-29 | 2019-12-02 | 1d | 0d |  | start no earlier than 2019-04-11 | GC | 8h |  |
| 197 | 7.2 | infection control measures approval |  | 0.25d | 2019-11-29 | 2019-11-29 | 196 |  |  | 2019-12-02 | 2019-12-02 | 0.25d | 0d |  | start no earlier than 2019-03-14 | OWNER | 2h |  |
| 198 | 7.3 | temporary construction barriers |  | 1d | 2019-11-29 | 2019-12-02 | 197 |  |  | 2019-12-02 | 2019-12-03 | 1d | 0d |  | start no earlier than 2019-03-16 | DRYWALL/FRAMING | 8h |  |
| 199 | 7.4 | demolition |  | 4d | 2019-12-02 | 2019-12-06 | 198 |  |  | 2019-12-03 | 2019-12-09 | 4d | 0d |  | start no earlier than 2019-03-20 | DEMO | 32h |  |
| 200 | 7.5 | mep assessment of existing services for seismic |  | 1d | 2019-12-06 | 2019-12-09 | 197, 199 |  |  | 2019-12-09 | 2019-12-10 | 1d | 0d |  | start no earlier than 2019-03-16 | ELECTRICAL; MECHANICAL; FIRE SPRINKLER; LOW VOLTAGE | 32h |  |
| 201 | 7.6 | mep assessment of new services for seismic |  | 1d | 2019-12-09 | 2019-12-10 | 197, 200 |  |  | 2019-12-10 | 2019-12-11 | 1d | 0d |  | start no earlier than 2019-03-16 | ELECTRICAL; MECHANICAL; FIRE SPRINKLER; LOW VOLTAGE | 32h |  |
| 202 | 7.7 | site layout |  | 1d | 2019-12-10 | 2019-12-11 | 199, 201 |  |  | 2019-12-11 | 2019-12-12 | 1d | 0d |  | start no earlier than 2018-12-11 | GC | 8h |  |
| 203 | 7.8 | mep seismic shop drawings creation |  | 5d | 2019-12-11 | 2019-12-18 | 201, 200, 202 |  |  | 2019-12-12 | 2019-12-19 | 5d | 0d |  | start no earlier than 2019-03-21 | ELECTRICAL; MECHANICAL; FIRE SPRINKLER; LOW VOLTAGE | 160h |  |
| 204 | 7.9 | seor review and approval of seismic shops |  | 4d | 2019-12-18 | 2020-01-20 | 203 |  |  | 2019-12-19 | 2020-01-21 | 4d | 0d |  | start no earlier than 2019-03-28 | AOR | 32h |  |
| 205 | 7.10 | oshpd dse field approval of seismic shops |  | 4.75d | 2020-01-20 | 2020-01-24 | 204 |  |  | 2020-01-21 | 2020-01-28 | 4.75d | 0d |  | start no earlier than 2019-04-25 | IOR | 38h |  |
| 206 | 7.11 | coring |  | 2d | 2020-01-27 | 2020-01-28 | 202, 205 |  |  | 2020-01-28 | 2020-01-30 | 2d | 0d |  | start no earlier than 2019-03-27 | SAWCUT | 16h |  |
| 207 | 7.12 | walls framing |  | 5d | 2020-01-29 | 2020-03-02 | 202, 113, 206 |  |  | 2020-01-30 | 2020-03-04 | 5d | 0d |  | start no earlier than 2019-03-22 | DRYWALL/FRAMING | 40h |  |
| 208 | 7.13 | door frames |  | 1d | 2020-03-03 | 2020-03-03 | 207, 84 |  |  | 2020-03-04 | 2020-03-05 | 1d | 0d |  | start no earlier than 2019-03-29 | DOORS | 8h |  |
| 209 | 7.14 | framing inspections |  | 1d | 2020-03-04 | 2020-03-04 | 207, 208 |  |  | 2020-03-05 | 2020-03-06 | 1d | 0d |  | start no earlier than 2019-03-31 | IOR | 8h |  |
| 210 | 7.15 | **in wall rough ins** |  | 10d | 2020-03-05 | 2020-03-18 | 202, 206, 209 |  |  | 2020-03-06 | 2020-03-20 | 10d | 0d |  |  |  | 80h |  |
| 211 | 7.15.1 | plumbing |  | 5d | 2020-03-05 | 2020-03-11 | 60, 66 |  |  | 2020-03-06 | 2020-03-13 | 5d | 0d |  | start no earlier than 2019-03-24 | MECHANICAL | 40h |  |
| 212 | 7.15.2 | power |  | 5d | 2020-03-12 | 2020-03-18 | 42, 211 |  |  | 2020-03-13 | 2020-03-20 | 5d | 0d |  | start no earlier than 2019-03-24 | ELECTRICAL | 40h |  |
| 213 | 7.16 | in wall inspections oshpd |  | 1d | 2020-03-19 | 2020-03-19 | 210, 209, 211, 212 |  |  | 2020-03-20 | 2020-03-23 | 1d | 0d |  | start no earlier than 2019-04-04 | IOR | 8h |  |
| 214 | 7.17 | in wall inspections (corrections if any) |  | 15d | 2020-03-20 | 2020-04-09 | 210, 213 |  |  | 2020-03-23 | 2020-04-13 | 15d | 0d |  |  | IOR | 120h |  |

| ID | WBS | Task | Type | Duration | Start | Finish | Predecessors | Baseline start | Baseline finish | Baseline duration | Total slack | Constraint | Resources | Work |
| --- | --- | --- | --- | --- | --- | --- | --- | --- | --- | --- | --- | --- | --- | --- |
| 215 | 7.18 | **above ceiling rough-ins** |  | 37.75d | 2020-04-10 | 2020-06-02 | 202, 214 | 2020-04-13 | 2020-06-04 | 37.75d | 0d |  |  | 326h |
| 216 | 7.18.1 | hvac |  | 10d | 2020-04-10 | 2020-04-23 | 22, 202, 36, 28 | 2020-04-13 | 2020-04-27 | 10d | 0d | start no earlier than 2019-03-29 | MECHANICAL | 80h |
| 217 | 7.18.2 | plumbing |  | 5d | 2020-04-24 | 2020-04-30 | 60, 202, 66, 216 | 2020-04-27 | 2020-05-04 | 5d | 0d | start no earlier than 2019-03-29 | MECHANICAL | 40h |
| 218 | 7.18.3 | power |  | 10d | 2020-05-01 | 2020-05-14 | 42, 202, 217 | 2020-05-04 | 2020-05-18 | 10d | 0d | start no earlier than 2019-04-10 | ELECTRICAL | 80h |
| 219 | 7.18.4 | fire sprinkler |  | 1d | 2020-05-15 | 2020-05-15 | 147, 202, 218 | 2020-05-18 | 2020-05-19 | 1d | 0d | start no earlier than 2019-04-10 | FIRE SPRINKLER | 8h |
| 220 | 7.18.5 | above hard lids rough ins complete | milestone | 0d | 2020-05-15 | 2020-05-15 | 217, 219 | 2020-05-19 | 2020-05-19 | 0d | 0d | start no earlier than 2019-04-20 |  |  |
| 221 | 7.18.6 | above hard lids rough ins inspections |  | 1d | 2020-05-18 | 2020-05-18 | 220 | 2020-05-19 | 2020-05-20 | 1d | 0d | start no earlier than 2019-04-11 | IOR | 8h |
| 222 | 7.18.7 | mep seismic complete |  | 1d | 2020-05-19 | 2020-05-19 | 205, 221 | 2020-05-20 | 2020-05-21 | 1d | 0d | start no earlier than 2019-04-16 | FIRE SPRINKLER; ELECTRICAL; MECHANICAL; LOW VOLTAGE | 32h |
| 223 | 7.18.8 | above ceilings anchors inspections |  | 1d | 2020-05-20 | 2020-05-20 | 205, 222 | 2020-05-21 | 2020-05-22 | 1d | 0d | start no earlier than 2019-05-03 | IOR | 8h |
| 224 | 7.18.9 | ducting / piping insulation |  | 2d | 2020-05-21 | 2020-05-22 | 22, 216, 202, 217, 36, 28, 223 | 2020-05-22 | 2020-05-26 | 2d | 0d | start no earlier than 2019-05-16 | MECHANICAL | 16h |
| 225 | 7.18.10 | lighting |  | 4.75d | 2020-05-25 | 2020-05-29 | 10, 202, 16, 224 | 2020-05-26 | 2020-06-02 | 4.75d | 0d | start no earlier than 2019-04-17 | ELECTRICAL | 38h |
| 226 | 7.18.11 | lv chase |  | 2d | 2020-05-29 | 2020-06-02 | 202, 48, 225 | 2020-06-02 | 2020-06-04 | 2d | 0d | start no earlier than 2019-04-19 | LOW VOLTAGE | 16h |
| 227 | 7.19 | walls drywall |  | 4.75d | 2020-06-02 | 2020-06-09 | 152, 213, 214, 215 | 2020-06-04 | 2020-06-10 | 4.75d | 0d | start no earlier than 2019-04-05 | DRYWALL/FRAMING | 38h |
| 228 | 7.20 | hard lids ceiling framing |  | 1d | 2020-06-09 | 2020-06-10 | 113, 213, 214, 227 | 2020-06-11 | 2020-06-11 | 1d | 0d | start no earlier than 2019-04-10 | DRYWALL/FRAMING | 8h |
| 229 | 7.21 | hard lids drywall |  | 1d | 2020-06-10 | 2020-06-11 | 152, 228, 221 | 2020-06-12 | 2020-06-12 | 1d | 0d | start no earlier than 2019-05-05 | DRYWALL/FRAMING | 8h |
| 230 | 7.22 | drywall screw off inspection |  | 0.25d | 2020-06-11 | 2020-06-11 | 229, 227 | 2020-06-15 | 2020-06-15 | 0.25d | 0d | start no earlier than 2019-04-13 | IOR | 2h |
| 231 | 7.23 | drywall finish |  | 5d | 2020-06-11 | 2020-06-18 | 152, 230 | 2020-06-15 | 2020-06-22 | 5d | 0d | start no earlier than 2019-05-11 | DRYWALL/FRAMING | 40h |
| 232 | 7.24 | grid ceiling wires |  | 1d | 2020-06-18 | 2020-06-19 | 72, 228, 231 | 2020-06-22 | 2020-06-23 | 1d | 0d | start no earlier than 2019-04-14 | ACOUSTICAL CEILING | 8h |
| 233 | 7.25 | grid ceiling wires test |  | 1d | 2020-06-19 | 2020-06-22 | 232 | 2020-06-23 | 2020-06-24 | 1d | 0d | start no earlier than 2019-05-11 | IOR | 8h |
| 234 | 7.26 | top of walls fire safing |  | 3d | 2020-06-22 | 2020-06-25 | 232, 163, 233 | 2020-06-24 | 2020-06-29 | 3d | 0d | start no earlier than 2019-04-16 | FIREPROOF | 24h |
| 235 | 7.27 | paint |  | 2d | 2020-06-25 | 2020-06-29 | 174, 231, 234 | 2020-06-29 | 2020-07-01 | 2d | 0d | start no earlier than 2019-05-18 | PAINT | 16h |
| 236 | 7.28 | grid ceiling |  | 2d | 2020-06-29 | 2020-07-01 | 233, 72, 235 | 2020-07-01 | 2020-07-03 | 2d | 0d | start no earlier than 2019-04-21 | ACOUSTICAL CEILING | 16h |
| 237 | 7.29 | ceiling trim outs |  | 2d | 2020-07-01 | 2020-07-03 | 125, 158, 22, 10, 60, 236, 219, 225, 66, 16, 36, 28 | 2020-07-03 | 2020-07-07 | 2d | 0d | start no earlier than 2019-04-22 | ELECTRICAL; MECHANICAL; FIRE SPRINKLER; FIRE ALARM; NURSE CALL/INTERCOM | 80h |
| 238 | 7.30 | wall trim outs |  | 4d | 2020-07-03 | 2020-07-09 | 235, 125, 158, 22, 10, 60, 66, 16, 36, 28, 237 | 2020-07-07 | 2020-07-13 | 4d | 0d | start no earlier than 2019-04-21 | ELECTRICAL; MECHANICAL; FIRE SPRINKLER; FIRE ALARM; NURSE CALL/INTERCOM | 160h |
| 239 | 7.31 | above ceiling oshpd inspections |  | 1d | 2020-07-09 | 2020-07-10 | 215, 236, 237, 216, 217, 218, 219, 223, 224, 225, 226, 238 | 2020-07-13 | 2020-07-14 | 1d | 0d | start no earlier than 2019-04-23 | IOR | 8h |
| 240 | 7.32 | above ceiling inspections (corrections if any) |  | 1d | 2020-07-10 | 2020-07-13 | 239 | 2020-07-14 | 2020-07-15 | 1d | 0d | start no earlier than 2019-05-22 | IOR | 8h |
| 241 | 7.33 | doors |  | 2d | 2020-07-13 | 2020-07-15 | 235, 54, 240 | 2020-07-15 | 2020-07-17 | 2d | 0d | start no earlier than 2019-05-21 | DOORS | 16h |
| 242 | 7.34 | door hardware |  | 2d | 2020-07-15 | 2020-07-17 | 96, 235, 241 | 2020-07-17 | 2020-07-21 | 2d | 0d | start no earlier than 2019-05-21 | DOORS | 16h |
| 243 | 7.35 | lumicor panels |  | 2d | 2020-07-17 | 2020-07-21 | 235, 78, 242 | 2020-07-21 | 2020-07-23 | 2d | 0d | start no earlier than 2019-05-21 | CASEWORK | 16h |
| 244 | 7.36 | casework |  | 5d | 2020-07-21 | 2020-07-28 | 235, 90, 243 | 2020-07-23 | 2020-07-30 | 5d | 0d | start no earlier than 2019-05-21 | CASEWORK | 40h |
| 245 | 7.37 | fire sprinkler arm overs |  | 1d | 2020-07-28 | 2020-07-29 | 147, 235, 244 | 2020-07-30 | 2020-07-31 | 1d | 0d | start no earlier than 2019-04-24 | FIRE SPRINKLER | 8h |
| 246 | 7.38 | wall protection / handrails installations |  | 3d | 2020-07-29 | 2020-08-03 | 235, 119, 245 | 2020-07-31 | 2020-08-05 | 3d | 0d | start no earlier than 2019-04-25 | SPECIALTIES | 24h |
| 247 | 7.39 | ceiling tiles |  | 2d | 2020-08-03 | 2020-08-05 | 102, 236, 239, 240, 245, 246 | 2020-08-05 | 2020-08-07 | 2d | 0d | start no earlier than 2019-04-28 | ACOUSTICAL CEILING | 16h |
| 248 | 7.40 | floor prep |  | 2d | 2020-08-05 | 2020-08-07 | 108, 169, 244, 241, 242, 243, 246, 247 | 2020-08-07 | 2020-08-11 | 2d | 0d | start no earlier than 2019-05-01 | FLOORING; EPOXY FLOORS | 32h |
| 249 | 7.41 | resilient flooring |  | 3d | 2020-08-07 | 2020-08-12 | 108, 248 | 2020-08-11 | 2020-08-14 | 3d | 0d | start no earlier than 2019-06-06 | FLOORING | 24h |
| 250 | 7.42 | epoxy flooring |  | 3d | 2020-08-12 | 2020-08-17 | 169, 248, 249 | 2020-08-14 | 2020-08-19 | 3d | 0d | start no earlier than 2019-06-06 | EPOXY FLOORS | 24h |
| 251 | 7.43 | phase 1 final air balance |  | 3d | 2020-08-17 | 2020-08-20 | 248, 247, 250 | 2020-08-19 | 2020-08-24 | 3d | 0d | start no earlier than 2019-05-05 | MECHANICAL | 24h |
| 252 | 7.44 | wainscot installations |  | 2d | 2020-08-20 | 2020-08-24 | 136, 244, 251 | 2020-08-24 | 2020-08-26 | 2d | 0d | start no earlier than 2019-05-07 | SPECIALTIES | 16h |
| 253 | 7.45 | verified reports collected for oshpd occupancy |  | 5d | 2020-08-24 | 2020-08-31 | 248, 252 | 2020-08-26 | 2020-09-02 | 5d | 0d | start no earlier than 2019-05-09 | AOR | 40h |
| 254 | 7.46 | phase 1 air balance approval |  | 4d | 2020-08-31 | 2020-09-04 | 251, 253 | 2020-09-02 | 2020-09-08 | 4d | 0d | start no earlier than 2019-06-07 | AOR | 32h |
| 255 | 7.47 | restroom trimouts/toilet accessories |  | 3d | 2020-09-04 | 2020-09-09 | 142, 252, 254 | 2020-09-08 | 2020-09-11 | 3d | 0d | start no earlier than 2019-05-10 | SPECIALTIES | 24h |
| 256 | 7.48 | phase 1 fa pre-testing |  | 1d | 2020-09-09 | 2020-09-10 | 237, 238, 255 | 2020-09-11 | 2020-09-14 | 1d | 0d | start no earlier than 2019-05-11 | FIRE ALARM | 8h |
| 257 | 7.49 | facility finish floors |  | 2d | 2020-09-10 | 2020-09-14 | 249, 250, 255, 256 | 2020-09-14 | 2020-09-16 | 2d | 0d | start no earlier than 2019-05-14 | OWNER | 16h |
| 258 | 7.50 | facility move furniture etc. into area |  | 3d | 2020-09-14 | 2020-09-17 | 257 | 2020-09-16 | 2020-09-21 | 3d | 0d | start no earlier than 2019-06-12 | OWNER | 24h |
| 259 | 7.51 | oshpd occupancy phase 1 |  | 10d | 2020-09-17 | 2020-10-01 | 256, 213, 239, 253, 254, 258 | 2020-09-21 | 2020-10-05 | 10d | 0d | start no earlier than 2019-05-19 |  | 80h |

| ID | WBS | Task | Duration | Start | Finish | Predecessors | Baseline start | Baseline finish | Baseline duration | Total slack | Constraint | Resources | Work |
| --- | --- | --- | --- | --- | --- | --- | --- | --- | --- | --- | --- | --- | --- |
| 260 | 8 | **phase 2 (e) nurse station area construction** | 116.75d | 2020-10-01 | 2021-03-15 | 195, 258, 259 | 2020-10-05 | 2021-03-16 | 116.75d | 0d |  |  | 1286h |
| 261 | 8.1 | infection control set up | 0.75d | 2020-10-01 | 2020-10-02 | 195 | 2020-10-05 | 2020-10-05 | 0.75d | 0d | start no earlier than 2018-10-02 | GC | 6h |
| 262 | 8.2 | infection control measures approval | 0.25d | 2020-10-02 | 2020-10-02 | 261 | 2020-10-06 | 2020-10-06 | 0.25d | 0d | start no earlier than 2018-10-03 | OWNER | 2h |
| 263 | 8.3 | temporary construction barriers | 2d | 2020-10-02 | 2020-10-06 | 262 | 2020-10-06 | 2020-10-08 | 2d | 0d | start no earlier than 2018-10-01 | DRYWALL/FRAMING | 16h |
| 264 | 8.4 | mep assessment of existing services for seismic | 1d | 2020-10-06 | 2020-10-07 | 262, 263 | 2020-10-08 | 2020-10-09 | 1d | 0d | start no earlier than 2018-09-01 | ELECTRICAL; MECHANICAL; FIRE SPRINKLER; LOW VOLTAGE | 32h |
| 265 | 8.5 | mep assessment of new services for seismic | 1d | 2020-10-07 | 2020-10-08 | 262, 264 | 2020-10-09 | 2020-10-12 | 1d | 0d | start no earlier than 2018-09-01 | ELECTRICAL; MECHANICAL; FIRE SPRINKLER; LOW VOLTAGE | 32h |
| 266 | 8.6 | demolition | 3d | 2020-10-08 | 2020-10-13 | 263, 265 | 2020-10-12 | 2020-10-15 | 3d | 0d | start no earlier than 2018-10-06 | DEMO | 24h |
| 267 | 8.7 | site layout | 1d | 2020-10-13 | 2020-10-14 | 266 | 2020-10-15 | 2020-10-16 | 1d | 0d | start no earlier than 2018-10-09 | GC | 8h |
| 268 | 8.8 | mep seismic shop drawings creation | 5d | 2020-10-14 | 2020-10-21 | 264, 265, 267 | 2020-10-16 | 2020-10-23 | 5d | 0d | start no earlier than 2018-10-02 | ELECTRICAL; MECHANICAL; FIRE SPRINKLER; LOW VOLTAGE | 160h |
| 269 | 8.9 | seor review and approval of seismic shops | 5d | 2020-10-21 | 2020-10-28 | 268 | 2020-10-23 | 2020-10-30 | 5d | 0d | start no earlier than 2018-10-12 | AOR | 40h |
| 270 | 8.10 | oshpd dse field approval of seismic shops | 1d | 2020-10-28 | 2020-10-29 | 269 | 2020-10-30 | 2020-11-02 | 1d | 0d | start no earlier than 2018-09-18 | IOR | 8h |
| 271 | 8.11 | framing | 2.5d | 2020-10-29 | 2020-11-03 | 113, 267, 270 | 2020-11-02 | 2020-11-04 | 2.5d | 0d | start no earlier than 2018-10-12 | DRYWALL/FRAMING | 20h |
| 272 | 8.12 | door frames | 0.75d | 2020-11-03 | 2020-11-03 | 84, 268, 271 | 2020-11-04 | 2020-11-05 | 0.75d | 0d | start no earlier than 2018-09-11 | DOORS | 6h |
| 273 | 8.13 | framing inspections | 0.25d | 2020-11-04 | 2020-11-04 | 271, 272 | 2020-11-05 | 2020-11-05 | 0.25d | 0d | start no earlier than 2018-09-17 | IOR | 2h |
| 274 | 8.14 | **above ceiling rough ins** | 37d | 2020-11-04 | 2020-12-25 | 273 | 2020-11-05 | 2020-12-28 | 37d | 0d |  |  | 320h |
| 275 | 8.14.1 | hvac | 9.25d | 2020-11-04 | 2020-11-17 | 22, 273, 36, 28 | 2020-11-05 | 2020-11-18 | 9.25d | 0d | start no earlier than 2018-09-20 | MECHANICAL | 74h |
| 276 | 8.14.2 | plumbing | 9.75d | 2020-11-17 | 2020-12-01 | 60, 39, 66, 275 | 2020-11-19 | 2020-12-02 | 9.75d | 0d | start no earlier than 2018-09-20 | MECHANICAL | 78h |
| 277 | 8.14.3 | power | 9.75d | 2020-12-01 | 2020-12-14 | 42, 273, 276 | 2020-12-02 | 2020-12-16 | 9.75d | 0d | start no earlier than 2018-09-20 | ELECTRICAL | 78h |
| 278 | 8.14.4 | fire sprinkler | 1d | 2020-12-15 | 2020-12-15 | 147, 273, 277 | 2020-12-16 | 2020-12-17 | 1d | 0d | start no earlier than 2018-09-29 | FIRE SPRINKLER | 8h |
| 279 | 8.14.5 | mep seismic complete | 1d | 2020-12-16 | 2020-12-16 | 278, 270 | 2020-12-17 | 2020-12-18 | 1d | 0d | start no earlier than 2018-09-24 | FIRE SPRINKLER; ELECTRICAL; MECHANICAL; LOW VOLTAGE | 32h |
| 280 | 8.14.6 | above ceilings anchors inspections | 1d | 2020-12-17 | 2020-12-17 | 279 | 2020-12-18 | 2020-12-21 | 1d | 0d | start no earlier than 2018-09-28 | IOR | 8h |
| 281 | 8.14.7 | ducting / piping insulation | 0.5d | 2020-12-18 | 2020-12-18 | 22, 275, 36, 28, 280 | 2020-12-21 | 2020-12-21 | 0.5d | 0d | start no earlier than 2018-10-31 | MECHANICAL | 4h |
| 282 | 8.14.8 | lighting | 4.75d | 2020-12-18 | 2020-12-25 | 10, 273, 16, 281 | 2020-12-22 | 2020-12-28 | 4.75d | 0d | start no earlier than 2018-09-27 | ELECTRICAL | 38h |
| 283 | 8.15 | above ceiling inspections | 1d | 2020-12-25 | 2020-12-28 | 274, 275, 276, 277, 280, 281, 282 | 2020-12-28 | 2020-12-29 | 1d | 0d | start no earlier than 2018-10-02 | IOR | 8h |

| ID | WBS | Task | Duration | Start | Finish | Predecessors | Baseline start | Baseline finish | Baseline duration | Total slack | Constraint | Resources | Work |
| --- | --- | --- | --- | --- | --- | --- | --- | --- | --- | --- | --- | --- | --- |
| 284 | 8.16 | **in wall rough ins** | 6d | 2020-12-28 | 2021-01-05 | 273, 283 | 2020-12-29 | 2021-01-06 | 6d | 0d |  |  | 48h |
| 285 | 8.16.1 | plumbing | 3d | 2020-12-28 | 2020-12-31 | 60, 273, 66 | 2020-12-29 | 2021-01-01 | 3d | 0d | start no earlier than 2018-09-20 | MECHANICAL | 24h |
| 286 | 8.16.2 | power | 3d | 2020-12-31 | 2021-01-05 | 42, 273, 285 | 2021-01-01 | 2021-01-06 | 3d | 0d | start no earlier than 2018-09-20 | ELECTRICAL | 24h |
| 287 | 8.17 | in wall oshpd inspections | 1d | 2021-01-05 | 2021-01-06 | 284, 285, 286 | 2021-01-06 | 2021-01-07 | 1d | 0d | start no earlier than 2018-09-17 | IOR | 8h |
| 288 | 8.18 | in wall inspections (corrections if any) | 1d | 2021-01-06 | 2021-01-07 | 287 | 2021-01-07 | 2021-01-08 | 1d | 0d | start no earlier than 2018-09-20 | IOR | 8h |
| 289 | 8.19 | drywall | 2d | 2021-01-07 | 2021-01-11 | 152, 287, 288 | 2021-01-08 | 2021-01-12 | 2d | 0d | start no earlier than 2018-10-21 | DRYWALL/FRAMING | 16h |
| 290 | 8.20 | drywall screw off inspection | 0.5d | 2021-01-11 | 2021-01-11 | 289, 288 | 2021-01-12 | 2021-01-13 | 0.5d | 0d | start no earlier than 2018-10-24 | IOR | 4h |
| 291 | 8.21 | drywall finish | 5d | 2021-01-11 | 2021-01-18 | 290, 152 | 2021-01-13 | 2021-01-20 | 5d | 0d | start no earlier than 2018-10-23 | DRYWALL/FRAMING | 40h |
| 292 | 8.22 | grid ceiling wires | 0.75d | 2021-01-18 | 2021-01-19 | 72, 273, 291 | 2021-01-20 | 2021-01-20 | 0.75d | 0d | start no earlier than 2018-09-24 | ACOUSTICAL CEILING | 6h |
| 293 | 8.23 | grid ceiling wires test | 0.25d | 2021-01-19 | 2021-01-19 | 292 | 2021-01-21 | 2021-01-21 | 0.25d | 0d | start no earlier than 2018-09-19 | IOR | 2h |
| 294 | 8.24 | paint | 2d | 2021-01-19 | 2021-01-21 | 174, 291, 293 | 2021-01-21 | 2021-01-25 | 2d | 0d | start no earlier than 2018-09-25 | PAINT | 16h |
| 295 | 8.25 | wall/ceiling trim outs | 5d | 2021-01-21 | 2021-01-28 | 22, 10, 48, 158, 125, 294, 16, 36, 28 | 2021-01-25 | 2021-02-01 | 5d | 0d | start no earlier than 2018-11-03 | ELECTRICAL; MECHANICAL; FIRE SPRINKLER; FIRE ALARM; NURSE CALL/INTERCOM | 200h |
| 296 | 8.26 | grid ceiling | 1d | 2021-01-28 | 2021-01-29 | 72, 293, 294, 295 | 2021-02-01 | 2021-02-02 | 1d | 0d | start no earlier than 2018-09-29 | ACOUSTICAL CEILING | 8h |
| 297 | 8.27 | oshpd above ceiling inspections | 1d | 2021-01-29 | 2021-02-01 | 296, 283 | 2021-02-02 | 2021-02-03 | 1d | 0d | start no earlier than 2018-10-08 | IOR | 8h |
| 298 | 8.28 | above ceiling inspections (corrections if any) | 1d | 2021-02-01 | 2021-02-02 | 297 | 2021-02-03 | 2021-02-04 | 1d | 0d | start no earlier than 2018-10-09 | IOR | 8h |
| 299 | 8.29 | doors | 2d | 2021-02-02 | 2021-02-04 | 54, 294, 298 | 2021-02-04 | 2021-02-08 | 2d | 0d | start no earlier than 2018-09-29 | DOORS | 16h |
| 300 | 8.30 | door hardware | 2d | 2021-02-04 | 2021-02-08 | 96, 294, 299 | 2021-02-08 | 2021-02-10 | 2d | 0d | start no earlier than 2018-09-29 | DOORS | 16h |
| 301 | 8.31 | ceiling tiles | 1d | 2021-02-08 | 2021-02-09 | 102, 297, 300 | 2021-02-10 | 2021-02-11 | 1d | 0d | start no earlier than 2018-10-08 | ACOUSTICAL CEILING | 8h |
| 302 | 8.32 | floor prep | 1d | 2021-02-09 | 2021-02-10 | 108, 301, 299, 300 | 2021-02-11 | 2021-02-12 | 1d | 0d | start no earlier than 2018-10-08 | FLOORING | 8h |
| 303 | 8.33 | resilient flooring | 1d | 2021-02-10 | 2021-02-11 | 108, 302 | 2021-02-12 | 2021-02-15 | 1d | 0d | start no earlier than 2018-11-09 | FLOORING | 8h |
| 304 | 8.34 | phase 2 final air balance | 2d | 2021-02-11 | 2021-02-15 | 302, 301, 303 | 2021-02-15 | 2021-02-17 | 2d | 0d | start no earlier than 2018-10-12 | MECHANICAL | 16h |
| 305 | 8.35 | verified reports collected for oshpd occupancy | 5d | 2021-02-15 | 2021-02-22 | 302, 304 | 2021-02-17 | 2021-02-24 | 5d | 0d | start no earlier than 2018-10-12 |  | 40h |
| 306 | 8.36 | phase 2 air balance approval | 3.75d | 2021-02-22 | 2021-02-26 | 304, 305 | 2021-02-24 | 2021-03-01 | 3.75d | 0d | start no earlier than 2018-11-12 | AOR | 30h |
| 307 | 8.37 | phase 2 fa pre-testing | 1d | 2021-02-26 | 2021-03-01 | 304, 295, 306 | 2021-03-02 | 2021-03-02 | 1d | 0d | start no earlier than 2018-10-16 | FIRE SPRINKLER | 8h |
| 308 | 8.38 | oshpd occupancy phase 2 | 10d | 2021-03-01 | 2021-03-15 | 306, 305, 307, 287, 297, 303 | 2021-03-03 | 2021-03-16 | 10d | 0d | start no earlier than 2018-10-22 |  | 80h |

| ID | WBS | Task | Type | Duration | Start | Finish | Predecessors | Baseline start | Baseline finish | Baseline duration | Total slack | Free slack | Constraint | Resources | Work |
| --- | --- | --- | --- | --- | --- | --- | --- | --- | --- | --- | --- | --- | --- | --- | --- |
| 309 | 9 | **phase 3 main area construction work** |  | 692d | 2021-03-15 | 2023-11-08 | 194, 260 | 2021-03-17 | 2023-11-09 | 692d | 0d |  |  |  | 9874.87h |
| 310 | 9.1 | **phase 3.1 occupied area const. work (phase 1)** |  | 512d | 2021-03-15 | 2023-03-01 | 195 | 2021-03-17 | 2023-03-02 | 512d | 0d |  |  |  | 2667.6h |
| 311 | 9.1.1 | infection control set up |  | 1.75d | 2021-03-15 | 2021-03-17 | 195 | 2021-03-17 | 2021-03-18 | 1.75d | 201.5d | 0d | start no earlier than 2019-06-28 | GC | 14h |
| 312 | 9.1.2 | infection control measures approval |  | 0.25d | 2021-03-17 | 2021-03-17 | 311 | 2021-03-18 | 2021-03-18 | 0.25d | 201.5d | 0d | start no earlier than 2019-06-28 | OWNER | 2h |
| 313 | 9.1.3 | temporary barricades |  | 2d | 2021-03-17 | 2021-03-19 | 312 | 2021-03-19 | 2021-03-22 | 2d | 201.5d | 0d | start no earlier than 2019-06-30 | DRYWALL/FRAMING | 16h |
| 314 | 9.1.4 | demolition |  | 5d | 2021-03-19 | 2021-03-26 | 313 | 2021-03-23 | 2021-03-29 | 5d | 201.5d | 0d | start no earlier than 2019-06-04 | DEMO | 40h |
| 315 | 9.1.5 | site layout |  | 1.5d | 2021-03-26 | 2021-03-29 | 314 | 2021-03-30 | 2021-03-31 | 1.5d | 201.5d | 0d | start no earlier than 2019-06-18 | GC; ELECTRICAL; MECHANICAL | 36h |
| 316 | 9.1.6 | coring |  | 0.5d | 2021-03-30 | 2021-03-30 | 315 | 2021-03-31 | 2021-03-31 | 0.5d | 201.5d | 0d | start no earlier than 2019-07-13 | SAWCUT | 4h |
| 317 | 9.1.7 | rated walls framing |  | 5.5d | 2021-03-30 | 2021-04-06 | 315, 113, 316 | 2021-04-01 | 2021-04-08 | 5.5d | 201.5d | 0d | start no earlier than 2019-07-13 | DRYWALL/FRAMING | 44h |
| 318 | 9.1.8 | other walls framing |  | 3.5d | 2021-04-07 | 2021-04-12 | 317, 113 | 2021-04-08 | 2021-04-13 | 3.5d | 201.5d | 0d | start no earlier than 2019-07-19 | DRYWALL/FRAMING | 28h |
| 319 | 9.1.9 | soffits / hard lids framing |  | 4d | 2021-04-12 | 2021-04-16 | 318, 113 | 2021-04-14 | 2021-04-19 | 4d | 201.5d | 0d | start no earlier than 2019-07-30 | DRYWALL/FRAMING | 32h |
| 320 | 9.1.10 | door frames |  | 2d | 2021-04-16 | 2021-04-20 | 318, 84, 319 | 2021-04-20 | 2021-04-21 | 2d | 201.5d | 0d | start no earlier than 2019-07-02 | DOORS | 16h |
| 321 | 9.1.11 | framing inspections |  | 2d | 2021-04-20 | 2021-04-22 | 317, 318, 319, 320 | 2021-04-22 | 2021-04-23 | 2d | 201.5d | 0d | start no earlier than 2019-08-02 | IOR | 16h |
| 322 | 9.1.12 | **in wall rough ins** |  | 42d | 2021-04-22 | 2021-06-21 | 317, 316, 321 | 2021-04-26 | 2021-06-22 | 42d | 201.5d | 0d |  |  | 336h |
| 323 | 9.1.12.1 | power rated walls |  | 9d | 2021-04-22 | 2021-05-05 | 317, 42, 316 | 2021-04-26 | 2021-05-06 | 9d | 201.5d | 0d | start no earlier than 2018-10-23 | ELECTRICAL | 72h |
| 324 | 9.1.12.2 | plumbing |  | 9d | 2021-05-05 | 2021-05-18 | 317, 60, 316, 66, 323 | 2021-05-07 | 2021-05-19 | 9d | 201.5d | 0d | start no earlier than 2018-09-28 | MECHANICAL | 72h |
| 325 | 9.1.12.3 | power other walls |  | 9d | 2021-05-18 | 2021-05-31 | 317, 42, 324 | 2021-05-20 | 2021-06-01 | 9d | 201.5d | 0d | start no earlier than 2018-09-29 | ELECTRICAL | 72h |
| 326 | 9.1.12.4 | low voltage chases |  | 5d | 2021-05-31 | 2021-06-07 | 323, 317, 48, 325 | 2021-06-02 | 2021-06-08 | 5d | 201.5d | 0d | start no earlier than 2018-10-07 | ELECTRICAL | 40h |
| 327 | 9.1.12.5 | medical gases |  | 10d | 2021-06-07 | 2021-06-21 | 317, 324, 326 | 2021-06-09 | 2021-06-22 | 10d | 201.5d | 99.5d | start no earlier than 2018-10-12 | MECHANICAL | 80h |
| 328 | 9.1.13 | unistrut work |  | 5.5d | 2021-06-21 | 2021-06-28 | 318, 180, 322 | 2021-06-23 | 2021-06-30 | 5.5d | 201.5d | 0d | start no earlier than 2019-06-29 | STEEL [190%] | 83.6h |
| 329 | 9.1.14 | unistrut anchors inspections |  | 1d | 2021-06-29 | 2021-06-29 | 328 | 2021-06-30 | 2021-07-01 | 1d | 201.5d | 0d | start no earlier than 2019-08-01 | IOR | 8h |
| 330 | 9.1.15 | **above ceiling rough ins** |  | 93d | 2021-06-30 | 2021-11-05 | 315, 329 | 2021-07-01 | 2021-11-09 | 93d | 201.5d | 0d |  |  | 744h |
| 331 | 9.1.15.1 | mech straps / anchors |  | 3d | 2021-06-30 | 2021-07-02 | 315, 22, 36, 28 | 2021-07-01 | 2021-07-06 | 3d | 201.5d | 0d | start no earlier than 2018-09-22 | MECHANICAL | 24h |
| 332 | 9.1.15.2 | power |  | 10d | 2021-07-05 | 2021-07-16 | 315, 42, 331 | 2021-07-06 | 2021-07-20 | 10d | 201.5d | 0d | start no earlier than 2018-09-22 | ELECTRICAL | 80h |
| 333 | 9.1.15.3 | mechanical duct |  | 7d | 2021-07-19 | 2021-07-27 | 331, 22, 36, 28, 332 | 2021-07-20 | 2021-07-29 | 7d | 201.5d | 0d | start no earlier than 2018-10-21 | MECHANICAL | 56h |
| 334 | 9.1.15.4 | mechanical hydronic piping |  | 9d | 2021-07-28 | 2021-08-09 | 333, 22, 36, 28 | 2021-07-29 | 2021-08-11 | 9d | 201.5d | 0d | start no earlier than 2018-10-31 | MECHANICAL | 72h |
| 335 | 9.1.15.5 | lighting |  | 9d | 2021-08-10 | 2021-08-20 | 332, 10, 16, 334 | 2021-08-11 | 2021-08-24 | 9d | 201.5d | 0d | start no earlier than 2018-10-06 | ELECTRICAL | 72h |
| 336 | 9.1.15.6 | low voltage chase |  | 10d | 2021-08-23 | 2021-09-03 | 335, 48 | 2021-08-24 | 2021-09-07 | 10d | 201.5d | 0d | start no earlier than 2018-10-20 | ELECTRICAL | 80h |
| 337 | 9.1.15.7 | mechanical controls |  | 10d | 2021-09-06 | 2021-09-17 | 334, 22, 36, 28, 336 | 2021-09-07 | 2021-09-21 | 10d | 201.5d | 0d | start no earlier than 2018-11-13 | MECHANICAL | 80h |
| 338 | 9.1.15.8 | plumbing |  | 10d | 2021-09-20 | 2021-10-01 | 324, 60, 66, 337 | 2021-09-21 | 2021-10-05 | 10d | 201.5d | 0d | start no earlier than 2018-10-19 | MECHANICAL | 80h |
| 339 | 9.1.15.9 | med gas |  | 10d | 2021-10-04 | 2021-10-15 | 324, 60, 66, 338 | 2021-10-05 | 2021-10-19 | 10d | 201.5d | 0d | start no earlier than 2018-10-19 | MECHANICAL | 80h |
| 340 | 9.1.15.10 | all med gas rough ins complete prior to dw dust | milestone | 0d | 2021-10-15 | 2021-10-15 | 339 | 2021-10-19 | 2021-10-19 | 0d | 201.5d | 0d | start no earlier than 2018-11-10 | MECHANICAL |  |
| 341 | 9.1.15.11 | duct / piping insulation |  | 5d | 2021-10-18 | 2021-10-22 | 337, 22, 338, 36, 28, 340 | 2021-10-19 | 2021-10-26 | 5d | 201.5d | 0d | start no earlier than 2018-12-02 | MECHANICAL | 40h |
| 342 | 9.1.15.12 | fire alarm |  | 10d | 2021-10-25 | 2021-11-05 | 336, 158, 341 | 2021-10-26 | 2021-11-09 | 10d | 201.5d | 84d | start no earlier than 2018-11-08 | ELECTRICAL | 80h |
| 343 | 9.1.16 | oshpd in wall inspections |  | 1d | 2021-11-08 | 2021-11-08 | 322, 321, 325, 326, 327, 330 | 2021-11-09 | 2021-11-10 | 1d | 201.5d | 0d | start no earlier than 2019-07-24 | IOR | 8h |
| 344 | 9.1.17 | in wall inspections (corrections if any) |  | 2d | 2021-11-09 | 2021-11-10 | 343 | 2021-11-10 | 2021-11-12 | 2d | 201.5d | 0d | start no earlier than 2019-07-25 | IOR | 16h |
| 345 | 9.1.18 | drywall |  | 4.75d | 2021-11-11 | 2021-11-17 | 343, 152, 340, 344 | 2021-11-12 | 2021-11-19 | 4.75d | 201.5d | 0d | start no earlier than 2019-08-24 | DRYWALL/FRAMING | 38h |
| 346 | 9.1.19 | drywall screw off inspections |  | 0.25d | 2021-11-17 | 2021-11-17 | 345 | 2021-11-19 | 2021-11-19 | 0.25d | 201.5d | 0d | start no earlier than 2019-08-29 | IOR | 2h |
| 347 | 9.1.20 | drywall finish |  | 7d | 2021-11-18 | 2021-11-26 | 346, 152 | 2021-11-19 | 2021-11-30 | 7d | 201.5d | 0d | start no earlier than 2019-09-01 | DRYWALL/FRAMING | 56h |
| 348 | 9.1.21 | grid ceiling wires |  | 2d | 2021-11-29 | 2021-11-30 | 346, 72, 347 | 2021-11-30 | 2021-12-02 | 2d | 201.5d | 0d | start no earlier than 2019-09-01 | ACOUSTICAL CEILING | 16h |
| 349 | 9.1.22 | grid ceiling wires test |  | 1d | 2021-12-01 | 2021-12-01 | 348 | 2021-12-02 | 2021-12-03 | 1d | 201.5d | 0d | start no earlier than 2019-08-29 | IOR | 8h |
| 350 | 9.1.23 | drywall finish final sand and touch ups |  | 3d | 2021-12-02 | 2021-12-06 | 347, 349 | 2021-12-03 | 2021-12-08 | 3d | 201.5d | 0d | start no earlier than 2019-09-05 | DRYWALL/FRAMING | 24h |
| 351 | 9.1.24 | paint |  | 5d | 2021-12-07 | 2021-12-13 | 350, 174 | 2021-12-08 | 2021-12-15 | 5d | 201.5d | 0d | start no earlier than 2019-09-14 | PAINT | 40h |
| 352 | 9.1.25 | wall protection / handrails installations |  | 5d | 2021-12-14 | 2021-12-20 | 351, 119 | 2021-12-15 | 2021-12-22 | 5d | 201.5d | 0d | start no earlier than 2019-09-21 | SPECIALTIES | 40h |
| 353 | 9.1.26 | grid ceiling |  | 5d | 2021-12-21 | 2021-12-27 | 351, 72, 352 | 2021-12-22 | 2021-12-29 | 5d | 201.5d | 0d | start no earlier than 2019-09-21 | ACOUSTICAL CEILING | 40h |
| 354 | 9.1.27 | doors / hardware |  | 5d | 2021-12-28 | 2022-01-03 | 351, 54, 353 | 2021-12-29 | 2022-01-05 | 5d | 201.5d | 0d | finish no earlier than 2019-01-07 | DOORS | 40h |
| 355 | 9.1.28 | casework |  | 5d | 2022-01-04 | 2022-01-10 | 351, 90, 354 | 2022-01-05 | 2022-01-12 | 5d | 201.5d | 0d | start no earlier than 2019-09-21 | CASEWORK | 40h |
| 356 | 9.1.29 | fire sprinkler arm overs |  | 2d | 2022-01-11 | 2022-01-12 | 353, 147, 355 | 2022-01-12 | 2022-01-14 | 2d | 201.5d | 0d | start no earlier than 2019-10-01 | FIRE SPRINKLER | 16h |

| ID | WBS | Task | Duration | Start | Finish | Predecessors | Baseline start | Baseline finish | Baseline duration | Total slack | Free slack | Constraint | Resources | Work |
| --- | --- | --- | --- | --- | --- | --- | --- | --- | --- | --- | --- | --- | --- | --- |
| 357 | 9.1.30 | **wall/ceiling trim outs** | 35d | 2022-01-13 | 2022-03-02 | 353, 356 | 2022-01-14 | 2022-03-04 | 35d | 201.5d | 0d |  |  | 280h |
| 358 | 9.1.30.1 | mechanical | 5d | 2022-01-13 | 2022-01-19 | 353, 22, 36, 28 | 2022-01-14 | 2022-01-21 | 5d | 201.5d | 0d | start no earlier than 2019-01-03 | MECHANICAL | 40h |
| 359 | 9.1.30.2 | electrical wall | 5d | 2022-01-20 | 2022-01-26 | 353, 42, 358 | 2022-01-21 | 2022-01-28 | 5d | 201.5d | 0d | start no earlier than 2019-01-03 | ELECTRICAL | 40h |
| 360 | 9.1.30.3 | data | 5d | 2022-01-27 | 2022-02-02 | 353, 48, 359 | 2022-01-28 | 2022-02-04 | 5d | 201.5d | 0d | start no earlier than 2019-01-03 | LOW VOLTAGE | 40h |
| 361 | 9.1.30.4 | electrical ceilings | 5d | 2022-02-03 | 2022-02-09 | 353, 10, 16, 360 | 2022-02-04 | 2022-02-11 | 5d | 201.5d | 0d | start no earlier than 2019-01-03 | ELECTRICAL | 40h |
| 362 | 9.1.30.5 | fire alarm | 5d | 2022-02-10 | 2022-02-16 | 353, 158, 361 | 2022-02-11 | 2022-02-18 | 5d | 201.5d | 0d | start no earlier than 2019-01-03 | FIRE ALARM | 40h |
| 363 | 9.1.30.6 | plumbing (except toilets) | 5d | 2022-02-17 | 2022-02-23 | 353, 60, 66, 362 | 2022-02-18 | 2022-02-25 | 5d | 201.5d | 0d | start no earlier than 2019-01-03 | MECHANICAL | 40h |
| 364 | 9.1.30.7 | patient headwalls installations | 5d | 2022-02-24 | 2022-03-02 | 353, 363 | 2022-02-25 | 2022-03-04 | 5d | 201.5d | 8d | start no earlier than 2018-12-10 | MECHANICAL | 40h |
| 365 | 9.1.31 | above ceilings anchors inspections | 1d | 2022-03-03 | 2022-03-03 | 356, 357 | 2022-03-04 | 2022-03-07 | 1d | 201.5d | 0d | start no earlier than 2019-10-01 | IOR | 8h |
| 366 | 9.1.32 | above ceilings oshpd inspections | 1d | 2022-03-04 | 2022-03-04 | 365, 329, 330, 341, 342, 349, 356 | 2022-03-07 | 2022-03-08 | 1d | 201.5d | 0d | start no earlier than 2019-09-05 |  | 8h |
| 367 | 9.1.33 | above ceiling inspections corrections if any | 2d | 2022-03-07 | 2022-03-08 | 366 | 2022-03-08 | 2022-03-10 | 2d | 201.5d | 0d | start no earlier than 2019-10-04 | IOR | 16h |
| 368 | 9.1.34 | ceiling tiles | 4d | 2022-03-09 | 2022-03-14 | 367, 102, 357, 358, 359, 360, 361, 362, 363 | 2022-03-10 | 2022-03-16 | 4d | 201.5d | 0d | start no earlier than 2019-10-07 | ACOUSTICAL CEILING | 32h |
| 369 | 9.1.35 | patient headwalls med gas final connections | 5d | 2022-03-15 | 2022-03-21 | 364, 60, 66, 368 | 2022-03-16 | 2022-03-23 | 5d | 201.5d | 0d | start no earlier than 2019-10-07 | MECHANICAL | 40h |
| 370 | 9.1.36 | patient headwalls electrical final connections | 5d | 2022-03-22 | 2022-03-28 | 364, 42, 369 | 2022-03-23 | 2022-03-30 | 5d | 201.5d | 0d | start no earlier than 2019-10-07 | ELECTRICAL | 40h |
| 371 | 9.1.37 | patient headwalls data final connections | 2d | 2022-03-29 | 2022-03-30 | 364, 48, 370 | 2022-03-30 | 2022-04-01 | 2d | 201.5d |  | start no earlier than 2019-10-07 | LOW VOLTAGE | 16h |
| 372 | 9.1.38 | final med gas certifications | 2d | 2023-01-06 | 2023-01-10 | 508, 369, 371 | 2023-01-10 | 2023-01-11 | 2d | 0d |  | start no earlier than 2019-10-14 | OWNER | 16h |
| 373 | 9.1.39 | floor prep | 3d | 2023-01-10 | 2023-01-13 | 368, 108, 169, 352, 354, 355, 369, 370, 371, 372 | 2023-01-12 | 2023-01-16 | 3d | 0d |  | start no earlier than 2019-10-14 | FLOORING | 24h |
| 374 | 9.1.40 | epoxy flooring restrooms | 5d | 2023-01-13 | 2023-01-20 | 373, 169 | 2023-01-17 | 2023-01-23 | 5d | 0d |  | start no earlier than 2019-10-15 | MECHANICAL | 40h |
| 375 | 9.1.41 | resilient flooring | 15d | 2023-01-20 | 2023-02-10 | 373, 108, 374 | 2023-01-24 | 2023-02-13 | 15d | 0d |  | start no earlier than 2019-10-15 | FLOORING; EPOXY FLOORS | 240h |
| 376 | 9.1.42 | restroom wainscot installations | 5d | 2023-02-10 | 2023-02-17 | 374, 136, 375 | 2023-02-14 | 2023-02-20 | 5d | 0d |  | start no earlier than 2019-10-07 | SPECIALTIES | 40h |
| 377 | 9.1.43 | floor mounted equipment installations | 3d | 2023-02-17 | 2023-02-22 | 375, 376 | 2023-02-21 | 2023-02-23 | 3d | 0d |  | start no earlier than 2019-11-07 | GC | 24h |
| 378 | 9.1.44 | floor mounted equip. anchorage inspections | 1d | 2023-02-22 | 2023-02-23 | 377 | 2023-02-24 | 2023-02-24 | 1d | 0d |  | start no earlier than 2019-11-15 | IOR | 8h |
| 379 | 9.1.45 | restroom trimouts | 4d | 2023-02-23 | 2023-03-01 | 378, 142, 376 | 2023-02-27 | 2023-03-02 | 4d | 0d |  | start no earlier than 2019-10-22 | MECHANICAL | 32h |
| 380 | 9.2 | **phase 3.2 it room construction work** | 180d | 2023-03-01 | 2023-11-08 | 194, 310 | 2023-03-03 | 2023-11-09 | 180d | 0d |  |  |  | 1616h |
| 381 | 9.2.1 | site area fenced off | 2d | 2023-03-01 | 2023-03-03 | 194 | 2023-03-03 | 2023-03-06 | 2d | 0d |  | start no earlier than 2019-03-18 | GC | 16h |
| 382 | 9.2.2 | site layout | 2d | 2023-03-03 | 2023-03-07 | 381 | 2023-03-07 | 2023-03-08 | 2d | 0d |  | start no earlier than 2019-04-07 | GC | 16h |
| 383 | 9.2.3 | coring for bollards | 1.5d | 2023-03-07 | 2023-03-08 | 382 | 2023-03-09 | 2023-03-10 | 1.5d | 0d |  | start no earlier than 2019-03-18 | SAWCUT | 12h |
| 384 | 9.2.4 | roughen existing slab | 1.5d | 2023-03-09 | 2023-03-10 | 381, 383 | 2023-03-10 | 2023-03-13 | 1.5d | 0d |  | start no earlier than 2019-03-19 | SAWCUT | 12h |
| 385 | 9.2.5 | remove spoils | 1d | 2023-03-10 | 2023-03-13 | 384 | 2023-03-14 | 2023-03-14 | 1d | 0d |  | start no earlier than 2019-03-20 | SAWCUT | 8h |
| 386 | 9.2.6 | install bollards | 1.75d | 2023-03-13 | 2023-03-15 | 385, 130 | 2023-03-15 | 2023-03-16 | 1.75d | 0d |  | start no earlier than 2019-03-27 | CONCRETE | 14h |
| 387 | 9.2.7 | bollards pre-pour inspections | 0.25d | 2023-03-15 | 2023-03-15 | 386 | 2023-03-16 | 2023-03-16 | 0.25d | 0d |  | start no earlier than 2019-03-22 | IOR | 2h |
| 388 | 9.2.8 | bollards concrete pour | 1d | 2023-03-15 | 2023-03-16 | 387, 130 | 2023-03-17 | 2023-03-17 | 1d | 0d |  | start no earlier than 2019-03-28 | CONCRETE | 8h |
| 389 | 9.2.9 | rebar work | 5d | 2023-03-16 | 2023-03-23 | 385, 130, 388 | 2023-03-20 | 2023-03-24 | 5d | 0d |  | start no earlier than 2019-03-28 | CONCRETE | 40h |
| 390 | 9.2.10 | rebar testing / inspections | 1d | 2023-03-23 | 2023-03-24 | 389 | 2023-03-27 | 2023-03-27 | 1d | 0d |  | start no earlier than 2019-04-04 | IOR | 8h |
| 391 | 9.2.11 | pour concrete | 1d | 2023-03-24 | 2023-03-27 | 390, 130 | 2023-03-28 | 2023-03-28 | 1d | 0d |  | start no earlier than 2019-04-04 | CONCRETE | 8h |
| 392 | 9.2.12 | concrete cure time | 9.5d | 2023-03-27 | 2023-04-07 | 391, 388 | 2023-03-29 | 2023-04-11 | 9.5d | 0d |  | start no earlier than 2019-04-06 |  | 76h |
| 393 | 9.2.13 | layout for framing | 0.5d | 2023-04-10 | 2023-04-10 | 392 | 2023-04-11 | 2023-04-11 | 0.5d | 0d |  | start no earlier than 2019-04-18 | GC | 4h |
| 394 | 9.2.14 | framing | 5d | 2023-04-10 | 2023-04-17 | 393, 113 | 2023-04-12 | 2023-04-18 | 5d | 0d |  | start no earlier than 2019-04-20 | DRYWALL/FRAMING | 40h |
| 395 | 9.2.15 | door frames | 1d | 2023-04-17 | 2023-04-18 | 393, 84, 394 | 2023-04-19 | 2023-04-19 | 1d | 0d |  | start no earlier than 2019-04-26 | DOORS | 8h |
| 396 | 9.2.16 | framing inspections | 1d | 2023-04-18 | 2023-04-19 | 394, 395 | 2023-04-20 | 2023-04-20 | 1d | 0d |  | start no earlier than 2019-04-29 | IOR | 8h |

| ID | WBS | Task | Duration | Start | Finish | Predecessors | Baseline start | Baseline finish | Baseline duration | Total slack | Constraint | Resources | Work |
| --- | --- | --- | --- | --- | --- | --- | --- | --- | --- | --- | --- | --- | --- |
| 397 | 9.2.17 | **in wall rough ins** | 16d | 2023-04-19 | 2023-05-11 | 394, 396 | 2023-04-21 | 2023-05-12 | 16d | 0d |  |  | 128h |
| 398 | 9.2.17.1 | electrical | 10d | 2023-04-19 | 2023-05-03 | 394, 42 | 2023-04-21 | 2023-05-04 | 10d | 0d | start no earlier than 2018-07-30 | ELECTRICAL | 80h |
| 399 | 9.2.17.2 | data/security/controls | 5d | 2023-05-03 | 2023-05-10 | 394, 48, 398 | 2023-05-05 | 2023-05-11 | 5d | 0d | start no earlier than 2018-08-13 | LOW VOLTAGE | 40h |
| 400 | 9.2.17.3 | oshpd in wall inspections | 1d | 2023-05-10 | 2023-05-11 | 398, 399 | 2023-05-12 | 2023-05-12 | 1d | 0d | start no earlier than 2018-08-24 | IOR | 8h |
| 401 | 9.2.18 | in wall inspections (corrections if any) | 2d | 2023-05-11 | 2023-05-15 | 397, 396, 398, 399 | 2023-05-15 | 2023-05-16 | 2d | 0d | start no earlier than 2019-05-21 | IOR | 16h |
| 402 | 9.2.19 | **above ceiling rough ins** | 52d | 2023-05-15 | 2023-07-26 | 394, 401 | 2023-05-17 | 2023-07-27 | 52d | 0d |  |  | 416h |
| 403 | 9.2.19.1 | electrical | 10d | 2023-05-15 | 2023-05-29 | 394, 42 | 2023-05-17 | 2023-05-30 | 10d | 0d | start no earlier than 2018-08-10 | ELECTRICAL | 80h |
| 404 | 9.2.19.2 | mechanical unit | 5d | 2023-05-29 | 2023-06-05 | 394, 22, 36, 28, 403 | 2023-05-31 | 2023-06-06 | 5d | 0d | start no earlier than 2018-08-10 | MECHANICAL | 40h |
| 405 | 9.2.19.3 | data raceways | 10d | 2023-06-05 | 2023-06-19 | 403, 48, 404 | 2023-06-07 | 2023-06-20 | 10d | 0d | start no earlier than 2018-08-28 | LOW VOLTAGE | 80h |
| 406 | 9.2.19.4 | ducting | 10d | 2023-06-19 | 2023-07-03 | 404, 22, 36, 28, 405 | 2023-06-21 | 2023-07-04 | 10d | 0d | start no earlier than 2018-08-17 | MECHANICAL | 80h |
| 407 | 9.2.19.5 | chilled water piping | 10d | 2023-07-03 | 2023-07-17 | 404, 60, 66, 406 | 2023-07-05 | 2023-07-18 | 10d | 0d | start no earlier than 2018-08-17 | MECHANICAL | 80h |
| 408 | 9.2.19.6 | hvac controls | 3d | 2023-07-17 | 2023-07-20 | 406, 22, 36, 28, 407 | 2023-07-19 | 2023-07-21 | 3d | 0d | start no earlier than 2018-08-31 | MECHANICAL | 24h |
| 409 | 9.2.19.7 | fire sprinkler rough | 2d | 2023-07-20 | 2023-07-24 | 408, 147 | 2023-07-24 | 2023-07-25 | 2d | 0d | start no earlier than 2018-09-03 | FIRE SPRINKLER | 16h |
| 410 | 9.2.19.8 | duct / piping insulation | 2d | 2023-07-24 | 2023-07-26 | 408, 22, 407, 36, 28, 409 | 2023-07-26 | 2023-07-27 | 2d | 0d | start no earlier than 2018-09-03 | MECHANICAL | 16h |
| 411 | 9.2.20 | drywall | 2d | 2023-07-26 | 2023-07-28 | 401, 152, 402 | 2023-07-28 | 2023-07-31 | 2d | 0d | start no earlier than 2019-05-21 | DRYWALL/FRAMING | 16h |
| 412 | 9.2.21 | drywall screw off inspections | 1d | 2023-07-28 | 2023-07-31 | 411 | 2023-08-01 | 2023-08-01 | 1d | 0d | start no earlier than 2019-05-25 | IOR | 8h |
| 413 | 9.2.22 | drywall finish | 5d | 2023-07-31 | 2023-08-07 | 412, 152 | 2023-08-02 | 2023-08-08 | 5d | 0d | start no earlier than 2019-05-28 | DRYWALL/FRAMING | 40h |
| 414 | 9.2.23 | grid ceiling wires | 1d | 2023-08-07 | 2023-08-08 | 412, 72, 413 | 2023-08-09 | 2023-08-09 | 1d | 0d | start no earlier than 2019-05-29 | ACOUSTICAL CEILING | 8h |
| 415 | 9.2.24 | grid ceiling wires testing | 1d | 2023-08-08 | 2023-08-09 | 414 | 2023-08-10 | 2023-08-10 | 1d | 0d | start no earlier than 2019-05-29 | IOR | 8h |
| 416 | 9.2.25 | paint | 2d | 2023-08-09 | 2023-08-11 | 413, 174, 415 | 2023-08-11 | 2023-08-14 | 2d | 0d | start no earlier than 2019-06-04 | PAINT | 16h |
| 417 | 9.2.26 | doors / hardware | 1d | 2023-08-11 | 2023-08-14 | 416, 54, 96 | 2023-08-15 | 2023-08-15 | 1d | 0d | start no earlier than 2019-06-04 | DOORS | 8h |
| 418 | 9.2.27 | grid ceiling | 2d | 2023-08-14 | 2023-08-16 | 416, 72, 415, 417 | 2023-08-16 | 2023-08-17 | 2d | 0d | start no earlier than 2019-06-04 | ACOUSTICAL CEILING | 16h |
| 419 | 9.2.28 | wall trim outs | 3d | 2023-08-16 | 2023-08-21 | 416, 22, 48, 42, 60, 66, 36, 28, 418 | 2023-08-18 | 2023-08-22 | 3d | 0d | start no earlier than 2019-06-06 | ELECTRICAL; MECHANICAL | 48h |
| 420 | 9.2.29 | ceiling trim outs | 4.75d | 2023-08-21 | 2023-08-28 | 418, 22, 10, 147, 158, 409, 16, 36, 28, 419 | 2023-08-23 | 2023-08-29 | 4.75d | 0d | start no earlier than 2019-06-08 | ELECTRICAL; MECHANICAL; FIRE SPRINKLER; FIRE ALARM; LOW VOLTAGE | 190h |
| 421 | 9.2.30 | above ceilings anchors inspections | 0.25d | 2023-08-28 | 2023-08-28 | 420 | 2023-08-29 | 2023-08-29 | 0.25d | 0d | start no earlier than 2019-06-12 | IOR | 2h |
| 422 | 9.2.31 | above ceiling oshpd inspections | 1d | 2023-08-28 | 2023-08-29 | 421, 402, 405, 410, 415 | 2023-08-30 | 2023-08-30 | 1d | 0d | start no earlier than 2019-06-15 | IOR | 8h |
| 423 | 9.2.32 | above ceiling inspections (corrections if any) | 1d | 2023-08-29 | 2023-08-30 | 422 | 2023-08-31 | 2023-08-31 | 1d | 0d | start no earlier than 2019-06-18 | IOR | 8h |
| 424 | 9.2.33 | ceiling tiles | 1d | 2023-08-30 | 2023-08-31 | 421, 102, 423 | 2023-09-01 | 2023-09-01 | 1d | 0d | start no earlier than 2019-06-17 | ACOUSTICAL CEILING | 8h |
| 425 | 9.2.34 | floor prep | 1d | 2023-08-31 | 2023-09-01 | 424, 108, 417, 419 | 2023-09-04 | 2023-09-04 | 1d | 0d | start no earlier than 2019-06-17 | FLOORING | 8h |
| 426 | 9.2.35 | flooring | 2d | 2023-09-01 | 2023-09-05 | 425, 108 | 2023-09-05 | 2023-09-06 | 2d | 0d | start no earlier than 2019-06-19 | FLOORING | 16h |
| 427 | 9.2.36 | facility finish floors | 2d | 2023-09-05 | 2023-09-07 | 426 | 2023-09-07 | 2023-09-08 | 2d | 0d | start no earlier than 2019-06-24 | OWNER | 16h |
| 428 | 9.2.37 | final clean of it space | 1d | 2023-09-07 | 2023-09-08 | 427 | 2023-09-11 | 2023-09-11 | 1d | 0d | start no earlier than 2019-06-24 | OWNER | 8h |
| 429 | 9.2.38 | start up of hvac unit | 1d | 2023-09-08 | 2023-09-11 | 428 | 2023-09-12 | 2023-09-12 | 1d | 0d | start no earlier than 2019-06-25 | MECHANICAL | 8h |
| 430 | 9.2.39 | installation new it data racks / equipment | 10d | 2023-09-11 | 2023-09-25 | 428, 48, 429 | 2023-09-13 | 2023-09-26 | 10d | 0d | start no earlier than 2019-06-25 | LOW VOLTAGE | 80h |
| 431 | 9.2.40 | anchorage inspections data racks equipment | 1d | 2023-09-25 | 2023-09-26 | 430 | 2023-09-27 | 2023-09-27 | 1d | 0d | start no earlier than 2019-07-15 | IOR | 8h |
| 432 | 9.2.41 | it room ready for systems installations | 1d | 2023-09-26 | 2023-09-27 | 431, 429 | 2023-09-28 | 2023-09-28 | 1d | 0d | start no earlier than 2019-07-16 | LOW VOLTAGE | 8h |
| 433 | 9.2.42 | data runs / trim outs to floor above | 30d | 2023-09-27 | 2023-11-08 | 432, 48 | 2023-09-29 | 2023-11-09 | 30d | 0d | start no earlier than 2019-07-24 | LOW VOLTAGE | 240h |
| 434 | 9.3 | infection control set up | 2.75d | 2021-03-15 | 2021-03-18 | 194 | 2021-03-17 | 2021-03-19 | 2.75d | 0d | start no earlier than 2019-03-13 | GC | 22h |
| 435 | 9.4 | infection control measures approval | 0.25d | 2021-03-18 | 2021-03-18 | 434 | 2021-03-19 | 2021-03-19 | 0.25d | 0d | start no earlier than 2019-03-20 | OWNER | 2h |
| 436 | 9.5 | temporary barricades | 2d | 2021-03-18 | 2021-03-22 | 435 | 2021-03-22 | 2021-03-23 | 2d | 0d | start no earlier than 2019-03-21 | DRYWALL/FRAMING | 16h |
| 437 | 9.6 | demolition | 9d | 2021-03-22 | 2021-04-02 | 436 | 2021-03-24 | 2021-04-05 | 9d | 0d | start no earlier than 2019-03-25 | DEMO | 72h |
| 438 | 9.7 | site layout | 3d | 2021-04-02 | 2021-04-07 | 437 | 2021-04-06 | 2021-04-08 | 3d | 0d | start no earlier than 2019-04-02 | GC | 24h |
| 439 | 9.8 | mep assessment of existing services for seismic | 10d | 2021-04-07 | 2021-04-21 | 438 | 2021-04-09 | 2021-04-22 | 10d | 0d | start no earlier than 2019-04-11 | ELECTRICAL; MECHANICAL; FIRE SPRINKLER; LOW VOLTAGE | 320h |
| 440 | 9.9 | mep assessment of new services for seismic | 10d | 2021-04-21 | 2021-05-05 | 438, 439 | 2021-04-23 | 2021-05-06 | 10d | 0d | start no earlier than 2019-04-11 | ELECTRICAL; MECHANICAL; FIRE SPRINKLER; LOW VOLTAGE | 320h |
| 441 | 9.10 | mep seismic shop drawings creation (phase 3, 3.1, 3.2) | 9d | 2021-05-05 | 2021-05-18 | 440, 439 | 2021-05-07 | 2021-05-19 | 9d | 0d | start no earlier than 2019-05-10 | ELECTRICAL; MECHANICAL; FIRE SPRINKLER; LOW VOLTAGE | 288h |
| 442 | 9.11 | seor review and approval of seismic shops | 10d | 2021-05-18 | 2021-06-01 | 441 | 2021-05-20 | 2021-06-02 | 10d | 0d | start no earlier than 2019-05-23 | AOR | 80h |
| 443 | 9.12 | oshpd dse field approval of seismic shops | 1d | 2021-06-01 | 2021-06-02 | 442 | 2021-06-03 | 2021-06-03 | 1d | 0d | start no earlier than 2019-05-04 | IOR | 8h |
| 444 | 9.13 | coring | 2d | 2021-06-02 | 2021-06-04 | 438, 443 | 2021-06-04 | 2021-06-07 | 2d | 0d | start no earlier than 2019-04-25 | SAWCUT | 16h |

| ID | WBS | Task | Type | Duration | Start | Finish | Predecessors | Baseline start | Baseline finish | Baseline duration | Total slack | Constraint | Resources | Work |
| --- | --- | --- | --- | --- | --- | --- | --- | --- | --- | --- | --- | --- | --- | --- |
| 445 | 9.14 | **walls framing** |  | 22d | 2021-06-04 | 2021-07-06 | 438, 113, 444 | 2021-06-08 | 2021-07-07 | 22d | 0d |  |  | 176h |
| 446 | 9.14.1 | rated |  | 10d | 2021-06-04 | 2021-06-18 | 438 | 2021-06-08 | 2021-06-21 | 10d | 0d | start no earlier than 2018-07-30 | DRYWALL/FRAMING | 80h |
| 447 | 9.14.2 | non-rated |  | 6d | 2021-06-18 | 2021-06-28 | 446 | 2021-06-22 | 2021-06-29 | 6d | 0d | start no earlier than 2018-07-29 | DRYWALL/FRAMING | 48h |
| 448 | 9.14.3 | soffits |  | 6d | 2021-06-28 | 2021-07-06 | 446, 447 | 2021-06-30 | 2021-07-07 | 6d | 0d | start no earlier than 2018-07-28 | DRYWALL/FRAMING | 48h |
| 449 | 9.15 | door frames |  | 3d | 2021-07-06 | 2021-07-09 | 445, 84 | 2021-07-08 | 2021-07-12 | 3d | 0d | start no earlier than 2019-05-02 | DOORS | 24h |
| 450 | 9.16 | framing inspections |  | 2d | 2021-07-09 | 2021-07-13 | 445, 449 | 2021-07-13 | 2021-07-14 | 2d | 0d | start no earlier than 2019-05-03 | IOR | 16h |
| 451 | 9.17 | **in wall rough in** |  | 55d | 2021-07-13 | 2021-09-28 | 446, 444, 450 | 2021-07-15 | 2021-09-29 | 55d | 0d |  |  | 983.27h |
| 452 | 9.17.1 | medical gas |  | 10d | 2021-07-13 | 2021-07-27 | 446, 60, 66 | 2021-07-15 | 2021-07-28 | 10d | 0d | start no earlier than 2018-07-24 | MECHANICAL [770%] | 616h |
| 453 | 9.17.2 | power (rated walls) |  | 10d | 2021-07-27 | 2021-08-10 | 446, 42, 452 | 2021-07-29 | 2021-08-11 | 10d | 0d | start no earlier than 2018-07-24 | ELECTRICAL [109.1%] | 87.27h |
| 454 | 9.17.3 | medical gas continued |  | 5d | 2021-08-10 | 2021-08-17 | 447, 60, 66, 453 | 2021-08-12 | 2021-08-18 | 5d | 0d | start no earlier than 2018-06-22 | MECHANICAL | 40h |
| 455 | 9.17.4 | power (non-rated walls) |  | 10d | 2021-08-17 | 2021-08-31 | 447, 42, 454 | 2021-08-19 | 2021-09-01 | 10d | 0d | start no earlier than 2018-08-04 | ELECTRICAL | 80h |
| 456 | 9.17.5 | plumbing |  | 10d | 2021-08-31 | 2021-09-14 | 446, 60, 66, 455 | 2021-09-02 | 2021-09-15 | 10d | 0d | start no earlier than 2018-08-11 | MECHANICAL | 80h |
| 457 | 9.17.6 | low voltage chases |  | 10d | 2021-09-14 | 2021-09-28 | 452, 48, 456 | 2021-09-16 | 2021-09-29 | 10d | 0d | start no earlier than 2018-08-10 | LOW VOLTAGE | 80h |
| 458 | 9.18 | **above ceiling rough ins** |  | 126d | 2021-09-28 | 2022-03-23 | 438, 451 | 2021-09-30 | 2022-03-24 | 126d | 0d |  |  | 1008h |
| 459 | 9.18.1 | unistrut work |  | 10d | 2021-09-28 | 2021-10-12 | 446, 180 | 2021-09-30 | 2021-10-13 | 10d | 0d | start no earlier than 2018-08-07 | STEEL | 80h |
| 460 | 9.18.2 | unistrut anchors inspections |  | 1d | 2021-10-12 | 2021-10-13 | 459 | 2021-10-14 | 2021-10-14 | 1d | 0d | start no earlier than 2018-08-28 | IOR | 8h |
| 461 | 9.18.3 | med gas |  | 10d | 2021-10-13 | 2021-10-27 | 452, 60, 66, 460 | 2021-10-15 | 2021-10-28 | 10d | 0d | start no earlier than 2018-08-10 | MECHANICAL | 80h |
| 462 | 9.18.4 | med gas continued |  | 5d | 2021-10-27 | 2021-11-03 | 461, 60, 452, 66 | 2021-10-29 | 2021-11-04 | 5d | 0d | start no earlier than 2018-08-11 | MECHANICAL | 40h |
| 463 | 9.18.5 | mech straps / anchors |  | 5d | 2021-11-03 | 2021-11-10 | 22, 36, 28, 462 | 2021-11-05 | 2021-11-11 | 5d | 0d | start no earlier than 2018-08-13 | MECHANICAL | 40h |
| 464 | 9.18.6 | mechanical duct |  | 10d | 2021-11-10 | 2021-11-24 | 463, 22, 36, 28 | 2021-11-12 | 2021-11-25 | 10d | 0d | start no earlier than 2018-08-19 | MECHANICAL | 80h |
| 465 | 9.18.7 | mechanical hydronic piping |  | 10d | 2021-11-24 | 2021-12-08 | 464, 22, 36, 28 | 2021-11-26 | 2021-12-09 | 10d | 0d | start no earlier than 2018-09-02 | MECHANICAL | 80h |
| 466 | 9.18.8 | plumbing |  | 10d | 2021-12-08 | 2021-12-22 | 465, 60, 66 | 2021-12-10 | 2021-12-23 | 10d | 0d | start no earlier than 2018-09-16 | MECHANICAL | 80h |
| 467 | 9.18.9 | mechanical controls |  | 10d | 2021-12-22 | 2022-01-05 | 465, 22, 36, 28, 466 | 2021-12-24 | 2022-01-06 | 10d | 0d | start no earlier than 2018-09-16 | MECHANICAL | 80h |
| 468 | 9.18.10 | duct / piping insulation |  | 10d | 2022-01-05 | 2022-01-19 | 464, 465, 466, 467, 22, 36, 28 | 2022-01-07 | 2022-01-20 | 10d | 0d | start no earlier than 2018-09-30 | MECHANICAL | 80h |
| 469 | 9.18.11 | power |  | 10d | 2022-01-19 | 2022-02-02 | 463, 42, 468 | 2022-01-21 | 2022-02-03 | 10d | 0d | start no earlier than 2018-08-19 | ELECTRICAL | 80h |
| 470 | 9.18.12 | lighting |  | 10d | 2022-02-02 | 2022-02-16 | 469, 10, 16 | 2022-02-04 | 2022-02-17 | 10d | 0d | start no earlier than 2018-09-02 | ELECTRICAL | 80h |
| 471 | 9.18.13 | low voltage chase |  | 10d | 2022-02-16 | 2022-03-02 | 470, 48 | 2022-02-18 | 2022-03-03 | 10d | 0d | start no earlier than 2018-09-16 | LOW VOLTAGE | 80h |
| 472 | 9.18.14 | fire sprinkler (mains & branches) |  | 5d | 2022-03-02 | 2022-03-09 | 471, 147 | 2022-03-04 | 2022-03-10 | 5d | 0d | start no earlier than 2018-09-16 | FIRE SPRINKLER | 40h |
| 473 | 9.18.15 | mep seismic complete | milestone | 0d | 2022-03-09 | 2022-03-09 | 472, 443 | 2022-03-10 | 2022-03-10 | 0d | 0d | start no earlier than 2018-10-10 | FIRE SPRINKLER; ELECTRICAL; MECHANICAL; LOW VOLTAGE |  |
| 474 | 9.18.16 | fire alarm |  | 10d | 2022-03-09 | 2022-03-23 | 471, 158, 473 | 2022-03-11 | 2022-03-24 | 10d | 0d | start no earlier than 2018-09-30 | FIRE ALARM | 80h |
| 475 | 9.19 | all med gas rough ins complete prior to dw dust | milestone | 0d | 2022-03-23 | 2022-03-23 | 452, 454, 461, 462, 458 | 2022-03-24 | 2022-03-24 | 0d | 0d | start no earlier than 2019-06-10 |  |  |
| 476 | 9.20 | in wall oshpd inspections |  | 1d | 2022-03-23 | 2022-03-24 | 462, 450, 451, 453, 455, 456, 457, 475 | 2022-03-25 | 2022-03-25 | 1d | 0d | start no earlier than 2019-05-28 | IOR | 8h |
| 477 | 9.21 | in wall inspections (corrections if any) |  | 3d | 2022-03-24 | 2022-03-29 | 476 | 2022-03-28 | 2022-03-30 | 3d | 0d | start no earlier than 2019-06-19 | IOR | 24h |
| 478 | 9.22 | drywall |  | 10d | 2022-03-29 | 2022-04-12 | 152, 475, 477 | 2022-03-31 | 2022-04-13 | 10d | 0d | start no earlier than 2019-06-22 | DRYWALL/FRAMING | 80h |
| 479 | 9.23 | drywall screw off inspections |  | 1d | 2022-04-12 | 2022-04-13 | 478 | 2022-04-14 | 2022-04-14 | 1d | 0d | start no earlier than 2019-06-17 | IOR | 8h |
| 480 | 9.24 | drywall finish |  | 10d | 2022-04-13 | 2022-04-27 | 478, 152, 479 | 2022-04-15 | 2022-04-28 | 10d | 0d | start no earlier than 2019-06-20 | DRYWALL/FRAMING | 80h |
| 481 | 9.25 | grid ceiling wires |  | 3d | 2022-04-27 | 2022-05-02 | 479, 72, 480 | 2022-04-29 | 2022-05-03 | 3d | 0d | start no earlier than 2019-06-22 | ACOUSTICAL CEILING | 24h |
| 482 | 9.26 | grid ceiling wires test |  | 2d | 2022-05-02 | 2022-05-04 | 481 | 2022-05-04 | 2022-05-05 | 2d | 0d | start no earlier than 2019-07-11 | IOR | 16h |
| 483 | 9.27 | drywall finish final sand and touch ups |  | 4d | 2022-05-04 | 2022-05-10 | 480, 152, 482 | 2022-05-06 | 2022-05-11 | 4d | 0d | start no earlier than 2019-07-21 | DRYWALL/FRAMING | 32h |
| 484 | 9.28 | paint |  | 10d | 2022-05-10 | 2022-05-24 | 483, 174 | 2022-05-12 | 2022-05-25 | 10d | 0d | start no earlier than 2019-07-13 | PAINT | 80h |
| 485 | 9.29 | doors / hardware |  | 10d | 2022-05-24 | 2022-06-07 | 484, 54, 96 | 2022-05-26 | 2022-06-08 | 10d | 0d | start no earlier than 2019-08-08 | DOORS | 80h |
| 486 | 9.30 | casework |  | 10d | 2022-06-07 | 2022-06-21 | 484, 90, 485 | 2022-06-09 | 2022-06-22 | 10d | 0d | start no earlier than 2019-07-22 | CASEWORK | 80h |
| 487 | 9.31 | wall protection / handrails installations |  | 10d | 2022-06-21 | 2022-07-05 | 484, 119, 486 | 2022-06-23 | 2022-07-06 | 10d | 0d | start no earlier than 2019-08-08 | SPECIALTIES | 80h |
| 488 | 9.32 | grid ceiling main area south end |  | 10d | 2022-07-05 | 2022-07-19 | 484, 102, 487 | 2022-07-07 | 2022-07-20 | 10d | 0d | start no earlier than 2019-08-08 | ACOUSTICAL CEILING | 80h |
| 489 | 9.33 | grid ceiling north end |  | 5d | 2022-07-19 | 2022-07-26 | 488, 102 | 2022-07-21 | 2022-07-27 | 5d | 0d | start no earlier than 2019-08-29 | ACOUSTICAL CEILING | 40h |

| ID | WBS | Task | Duration | Start | Finish | Predecessors | Baseline start | Baseline finish | Baseline duration | Total slack | Free slack | Constraint | Resources | Work |
| --- | --- | --- | --- | --- | --- | --- | --- | --- | --- | --- | --- | --- | --- | --- |
| 490 | 9.34 | **wall trim outs** | 65d | 2022-07-26 | 2022-10-25 | 487, 489 | 2022-07-28 | 2022-10-26 | 65d | 0d |  |  |  | 520h |
| 491 | 9.34.1 | electrical wall trim outs | 10d | 2022-07-26 | 2022-08-09 | 487, 42 | 2022-07-28 | 2022-08-10 | 10d | 0d |  | start no earlier than 2018-12-03 | ELECTRICAL | 80h |
| 492 | 9.34.2 | data trim outs | 10d | 2022-08-09 | 2022-08-23 | 487, 48, 491 | 2022-08-11 | 2022-08-24 | 10d | 0d |  | start no earlier than 2018-12-03 | LOW VOLTAGE | 80h |
| 493 | 9.34.3 | patient headwalls installations | 10d | 2022-08-23 | 2022-09-06 | 487, 492 | 2022-08-25 | 2022-09-07 | 10d | 0d |  | start no earlier than 2018-12-03 | GC | 80h |
| 494 | 9.34.4 | headwall med gas final connections | 10d | 2022-09-06 | 2022-09-20 | 487, 60, 66, 493 | 2022-09-08 | 2022-09-21 | 10d | 0d |  | start no earlier than 2018-11-21 | MECHANICAL | 80h |
| 495 | 9.34.5 | headwall electrical final connections | 10d | 2022-09-20 | 2022-10-04 | 493, 42, 494 | 2022-09-22 | 2022-10-05 | 10d | 0d |  | start no earlier than 2018-11-26 | ELECTRICAL | 80h |
| 496 | 9.34.6 | headwall data final connections | 5d | 2022-10-04 | 2022-10-11 | 493, 48, 495 | 2022-10-06 | 2022-10-12 | 5d | 0d |  | start no earlier than 2018-12-03 | LOW VOLTAGE | 40h |
| 497 | 9.34.7 | plumbing trim outs except toilets | 10d | 2022-10-11 | 2022-10-25 | 492, 487, 60, 66, 496 | 2022-10-13 | 2022-10-26 | 10d | 0d |  | start no earlier than 2018-12-13 | MECHANICAL | 80h |
| 498 | 9.35 | **ceiling trim outs** | 42d | 2022-10-25 | 2022-12-22 | 488, 490 | 2022-10-27 | 2022-12-23 | 42d | 0d |  |  |  | 336h |
| 499 | 9.35.1 | mechanical trim outs south end | 10d | 2022-10-25 | 2022-11-08 | 488, 22, 36, 28 | 2022-10-27 | 2022-11-09 | 10d | 0d |  | start no earlier than 2018-12-03 | MECHANICAL | 80h |
| 500 | 9.35.2 | fire sprinkler arm overs | 5d | 2022-11-08 | 2022-11-15 | 489, 147, 499 | 2022-11-10 | 2022-11-16 | 5d | 0d |  | start no earlier than 2018-12-06 | FIRE SPRINKLER | 40h |
| 501 | 9.35.3 | electrical trim outs ceilings | 10d | 2022-11-15 | 2022-11-29 | 489, 42, 500 | 2022-11-17 | 2022-11-30 | 10d | 0d |  | start no earlier than 2018-12-06 | ELECTRICAL | 80h |
| 502 | 9.35.4 | mechanical trim outs north end | 10d | 2022-11-29 | 2022-12-13 | 499, 22, 36, 28, 501 | 2022-12-01 | 2022-12-14 | 10d | 0d |  | start no earlier than 2018-12-13 | MECHANICAL | 80h |
| 503 | 9.35.5 | fire alarm trim outs | 5d | 2022-12-13 | 2022-12-20 | 501, 158, 502 | 2022-12-15 | 2022-12-21 | 5d | 0d |  | start no earlier than 2018-12-19 | FIRE ALARM | 40h |
| 504 | 9.35.6 | above ceilings anchors inspections | 2d | 2022-12-20 | 2022-12-22 | 500, 503 | 2022-12-22 | 2022-12-23 | 2d | 0d |  | start no earlier than 2018-11-29 | IOR | 16h |
| 505 | 9.36 | above ceiling oshpd inspections | 1d | 2022-12-22 | 2022-12-23 | 490, 498, 458, 460, 468, 473, 474, 482, 502, 504 | 2022-12-26 | 2022-12-26 | 1d | 0d |  | start no earlier than 2019-09-06 | IOR | 8h |
| 506 | 9.37 | above ceiling inspections (corrections if any) | 3d | 2022-12-23 | 2022-12-28 | 505 | 2022-12-27 | 2022-12-29 | 3d | 0d |  | start no earlier than 2019-09-25 | IOR | 24h |
| 507 | 9.38 | final med gas certifications | 2d | 2022-12-28 | 2022-12-30 | 494, 506 | 2022-12-30 | 2023-01-02 | 2d | 0d |  | start no earlier than 2019-09-05 | OWNER | 16h |
| 508 | 9.39 | ceiling tiles | 5d | 2022-12-30 | 2023-01-06 | 505, 102, 506, 507 | 2023-01-03 | 2023-01-09 | 5d | 0d |  | start no earlier than 2019-09-11 | ACOUSTICAL CEILING | 40h |
| 509 | 9.40 | floor prep | 3d | 2023-01-06 | 2023-01-11 | 508, 108, 169, 485, 486, 491, 495, 496, 494, 497 | 2023-01-10 | 2023-01-12 | 3d | 150d | 0d | start no earlier than 2019-10-06 | FLOORING; EPOXY FLOORS | 48h |
| 510 | 9.41 | resilient flooring | 15d | 2023-01-11 | 2023-02-01 | 509, 108 | 2023-01-13 | 2023-02-02 | 15d | 150d | 0d | start no earlier than 2019-10-11 | FLOORING | 120h |
| 511 | 9.42 | epoxy flooring | 15d | 2023-02-01 | 2023-02-22 | 509, 169, 510 | 2023-02-03 | 2023-02-23 | 15d | 150d | 0d | start no earlier than 2019-10-11 | EPOXY FLOORS | 120h |
| 512 | 9.43 | restroom wainscot installations | 5d | 2023-02-22 | 2023-03-01 | 509, 136, 511 | 2023-02-24 | 2023-03-02 | 5d | 150d | 0d | start no earlier than 2019-10-09 | SPECIALTIES | 40h |
| 513 | 9.44 | restroom trimouts | 5d | 2023-03-01 | 2023-03-08 | 512, 142 | 2023-03-03 | 2023-03-09 | 5d | 150d | 0d | start no earlier than 2019-10-16 | SPECIALTIES | 40h |
| 514 | 9.45 | privacy curtain install | 3d | 2023-03-08 | 2023-03-13 | 510, 192, 4, 513 | 2023-03-10 | 2023-03-14 | 3d | 150d | 0d | start no earlier than 2019-10-16 | SPECIALTIES | 24h |
| 515 | 9.46 | floor mounted equipment installations | 3d | 2023-03-13 | 2023-03-16 | 510, 514 | 2023-03-15 | 2023-03-17 | 3d | 150d | 0d | start no earlier than 2019-10-16 | GC | 24h |
| 516 | 9.47 | floor mounted equip. anchorage inspections | 1d | 2023-03-16 | 2023-03-17 | 515 | 2023-03-20 | 2023-03-20 | 1d | 150d | 0d | start no earlier than 2019-10-20 | IOR | 8h |
| 517 | 9.48 | phase 3 final air balance | 9d | 2023-03-17 | 2023-03-30 | 510, 511, 516 | 2023-03-21 | 2023-03-31 | 9d | 150d | 0d | start no earlier than 2019-10-16 | MECHANICAL [88.9%] | 64h |
| 518 | 9.49 | phase 3 fa pre-testing | 1d | 2023-03-30 | 2023-03-31 | 517, 503 | 2023-04-03 | 2023-04-03 | 1d | 150d | 0d | start no earlier than 2019-10-29 | FIRE ALARM | 8h |
| 519 | 9.50 | verified reports collected for oshpd occupancy | 4d | 2023-03-31 | 2023-04-06 | 517, 518 | 2023-04-04 | 2023-04-07 | 4d | 150d | 0d | start no earlier than 2019-10-29 | GC | 32h |
| 520 | 9.51 | phase 3 final air balance approval | 4d | 2023-04-06 | 2023-04-12 | 517, 519 | 2023-04-10 | 2023-04-13 | 4d | 150d |  | start no earlier than 2019-11-14 | AOR | 32h |
| 521 | 10 | oshpd finals | 5d | 2023-11-08 | 2023-11-15 | 520, 343, 366, 401, 422, 476, 505, 507, 517, 518, 519, 260, 308, 309, 310, 372, 379, 380, 433, 513, 514, 516 | 2023-11-10 | 2023-11-16 | 5d | 0d |  |  |  |  |
| 522 | 11 | project closeout | 45d | 2023-11-15 | 2024-01-17 | 521 | 2023-11-17 | 2024-01-18 | 45d | 0d |  |  |  |  |
